# Quik Biz - Project Plan Template

Schedule from MS Project, 2007-01-01 to 2008-11-13, A marks actual dates.
TPS of Illinois, Incorporated

## Calendars

- Standard: Mon-Fri 08:00-12:00, 13:00-17:00; Sat-Sun off.

## Resources

| Resource |
| --- |
| SME |
| Process Analyst |
| Developer |
| Trainers |
| Stakeholder Support |
| Operations Manager |
| Business Solutions User Support Analyst |
| Production Control |
| Network Analyst |
| Business Analyst |
| Legacy Developer |
| Extranet Designer |
| Server Admin |
| Network Admin |
| Network Support |
| Reports Developer |
| Internal Audit |
| Business SME |

## Schedule

| ID | WBS | Task | Duration | Start | Finish | Predecessors | Complete | Remaining | Total slack | Free slack | Work |
| --- | --- | --- | --- | --- | --- | --- | --- | --- | --- | --- | --- |
| 1 | 1 | **[Enter Project Name]** | 488.03d | 2007-01-01 A | 2008-11-13 |  | 1% | 484.59d | 0d |  | 7629.87h |
| 2 | 1.1 | **Define Implementation Strategy - Detailed Approach/Impact Analysis** | 31d | 2007-01-01 | 2007-02-12 |  |  |  | 457.03d |  |  |
| 3 | 1.1.1 | **Detail Impact Analysis/Cost Benefit Analysis** | 31d | 2007-01-01 | 2007-02-12 |  |  |  | 457.03d |  |  |
| 4 | 1.1.1.1 | **Processes** | 8.83d | 2007-01-01 | 2007-01-11 |  |  |  | 479.21d |  |  |
| 5 | 1.1.1.1.1 | Develop\Review "As Is Process Maps" | 1.25d | 2007-01-01 | 2007-01-02 |  |  |  | 485.53d | 0d |  |
| 6 | 1.1.1.1.2 | Develop\Review "Future" Process Maps | 1.25d | 2007-01-02 | 2007-01-03 | 5 |  |  | 485.53d |  |  |
| 7 | 1.1.1.1.3 | Determine "Future" processes for rollout | 8.83d | 2007-01-01 | 2007-01-11 |  |  |  | 479.21d |  |  |
| 8 | 1.1.1.2 | **Change Management** | 6.2d | 2007-01-01 | 2007-01-09 |  |  |  | 480.68d |  |  |
| 9 | 1.1.1.2.1 | Validate Stakeholder Management Strategy | 0.5d | 2007-01-01 | 2007-01-01 |  |  |  | 486.03d | 0d |  |
| 10 | 1.1.1.2.2 | Prioritize strategies as a basis for tactical planning | 0.5d | 2007-01-01 | 2007-01-01 | 9 |  |  | 486.03d | 0d |  |
| 11 | 1.1.1.2.3 | Revisit Stakeholder Strategy | 1d | 2007-01-02 | 2007-01-02 | 10 |  |  | 486.03d |  |  |
| 12 | 1.1.1.2.4 | Identify Organizational Impacts of "Roll in" processes | 1d | 2007-01-01 | 2007-01-01 |  |  |  | 481.83d | 0d |  |
| 13 | 1.1.1.2.5 | Revisit Transition Strategy | 1d | 2007-01-02 | 2007-01-02 | 12 |  |  | 481.83d | 0d |  |
| 14 | 1.1.1.2.6 | Revisit Recruiting Strategy | 1d | 2007-01-03 | 2007-01-03 | 13 |  |  | 485.03d |  |  |
| 15 | 1.1.1.2.7 | Revisit Training Strategy | 3.2d | 2007-01-03 | 2007-01-08 | 13 |  |  | 481.83d | 0d |  |
| 16 | 1.1.1.2.8 | Revisit Communication Strategy | 1d | 2007-01-08 | 2007-01-09 | 15 |  |  | 481.83d |  |  |
| 17 | 1.1.1.2.9 | Review Current SOP's | 1.18d | 2007-01-01 | 2007-01-02 |  |  |  | 480.68d | 0d |  |
| 18 | 1.1.1.2.10 | Recommendation on creating/updating SOP's | 1.18d | 2007-01-02 | 2007-01-03 | 17 |  |  | 480.68d | 0d |  |
| 19 | 1.1.1.2.11 | Determine List of tasks to be done | 5d | 2007-01-01 | 2007-01-05 |  |  |  | 483.03d |  |  |
| 20 | 1.1.1.3 | **Technology** | 5.55d | 2007-01-01 | 2007-01-08 |  |  |  | 482.48d |  |  |
| 21 | 1.1.1.3.1 | **Legacy Changes** | 5d | 2007-01-01 | 2007-01-05 |  |  |  | 483.03d |  |  |
| 22 | 1.1.1.3.1.1 | Review Business Process Impacts | 1.25d | 2007-01-01 | 2007-01-02 |  |  |  | 483.03d | 0d |  |
| 23 | 1.1.1.3.1.2 | Confirm Business Requirements | 2.5d | 2007-01-02 | 2007-01-04 | 22 |  |  | 483.03d | 0d |  |
| 24 | 1.1.1.3.1.3 | Refine Estimates - Organizational Rollout | 1.25d | 2007-01-04 | 2007-01-05 | 23 |  |  | 483.03d |  |  |

| ID | WBS | Task | Duration | Start | Finish | Predecessors | Total slack | Free slack | Constraint |
| --- | --- | --- | --- | --- | --- | --- | --- | --- | --- |
| 25 | 1.1.1.3.2 | **Review and Confirm Deliverables** | 5.55d | 2007-01-01 | 2007-01-08 |  | 482.48d |  |  |
| 26 | 1.1.1.3.2.1 | Middleware Requirements | 2.8d | 2007-01-01 | 2007-01-03 |  | 482.48d | 0d |  |
| 27 | 1.1.1.3.2.2 | Interface Strategy | 1d | 2007-01-03 | 2007-01-04 | 26 | 482.48d | 0d |  |
| 28 | 1.1.1.3.2.3 | Instance Strategy | 0.75d | 2007-01-04 | 2007-01-05 | 27 | 482.48d | 0d |  |
| 29 | 1.1.1.3.2.4 | Conversion Strategy | 1d | 2007-01-05 | 2007-01-08 | 28 | 482.48d |  |  |
| 30 | 1.1.1.3.2.5 | Payment Matrix | 1d | 2007-01-01 | 2007-01-01 |  | 487.03d |  |  |
| 31 | 1.1.1.4 | **Facilities** | 13.35d | 2007-01-01 | 2007-01-18 |  | 474.68d |  |  |
| 32 | 1.1.1.4.1 | **Work Area** | 10.35d | 2007-01-01 | 2007-01-15 |  | 474.68d |  |  |
| 33 | 1.1.1.4.1.1 | Determine Requirements | 1.25d | 2007-01-01 | 2007-01-02 |  | 474.68d | 0d |  |
| 34 | 1.1.1.4.1.2 | Verify Location | 1.25d | 2007-01-02 | 2007-01-03 | 33 | 474.68d | 0d |  |
| 35 | 1.1.1.4.1.3 | Develop Budget | 1.25d | 2007-01-03 | 2007-01-04 | 34 | 474.68d | 0d |  |
| 36 | 1.1.1.4.1.4 | Develop Facilities Plan | 6.6d | 2007-01-04 | 2007-01-15 | 35 | 474.68d | 0d |  |
| 37 | 1.1.1.4.2 | Determine Requirements for Org Rollout | 3d | 2007-01-15 | 2007-01-18 | 36, 12 | 474.68d |  |  |
| 38 | 1.1.1.5 | **Project Management - Resources/Plan, Costs** | 31d | 2007-01-01 | 2007-02-12 |  | 457.03d |  |  |
| 39 | 1.1.1.5.1 | Define and Implement Project Controls | 8d | 2007-01-01 | 2007-01-10 |  | 480.03d |  | start no earlier than 2007-01-01 |
| 40 | 1.1.1.5.2 | Confirm Approach, Scope, Resources, Plan, Estimates, Benefits -- Part of Detailed Planning Sessions | 16d | 2007-01-01 | 2007-01-22 |  | 457.03d | 0d | start no earlier than 2007-01-01 |
| 41 | 1.1.1.5.3 | **Refine Approach, Plan, etc. for <dept>** | 5d | 2007-01-23 | 2007-01-29 | 40 | 457.03d |  |  |
| 42 | 1.1.1.5.3.1 | Org Rollout | 2.5d | 2007-01-23 | 2007-01-25 |  | 457.03d | 0d |  |
| 43 | 1.1.1.5.3.2 | Oracle Rollout | 2.5d | 2007-01-25 | 2007-01-29 | 42 | 457.03d | 0d |  |
| 44 | 1.1.1.5.4 | Revise Estimates based on using some <client> Standard templates | 2d | 2007-01-30 | 2007-01-31 | 43 | 465.03d |  |  |
| 45 | 1.1.1.5.5 | Roles and Resp. | 5d | 2007-01-03 | 2007-01-10 | 18 | 480.68d |  |  |
| 46 | 1.1.1.5.6 | Revise Budget Estimates | 4d | 2007-01-25 | 2007-01-30 | 43FS-3d | 457.03d | 0d |  |
| 47 | 1.1.1.5.7 | Cost / Benefit Analysis (BVA) | 4d | 2007-01-31 | 2007-02-05 | 46 | 457.03d | 0d |  |
| 48 | 1.1.1.5.8 | Document Case for change | 1d | 2007-02-06 | 2007-02-06 | 47 | 461.03d |  |  |
| 49 | 1.1.1.5.9 | Revise Project Charter | 3d | 2007-02-06 | 2007-02-08 | 47 | 457.03d | 0d |  |
| 50 | 1.1.1.5.10 | Recommendation | 2d | 2007-02-09 | 2007-02-12 | 49 | 457.03d |  |  |
| 51 | 1.1.2 | Obtain Approval on Staged Approach - Charter and Plan | 1d | 2007-01-01 | 2007-01-01 |  | 477.03d | 0d | start no earlier than 2007-01-01 |
| 52 | 1.1.3 | Communicate and Obtain Approval to Larger Stakeholder Group | 10d | 2007-01-02 | 2007-01-15 | 51 | 477.03d |  |  |

| ID | WBS | Task | Duration | Start | Finish | Predecessors | Complete | Remaining | Total slack | Free slack | Constraint | Work |
| --- | --- | --- | --- | --- | --- | --- | --- | --- | --- | --- | --- | --- |
| 53 | 1.2 | **Centralization - Roll-In** | 98.89d | 2007-01-01 A | 2007-05-17 |  | 3% | 96.01d | 389.14d |  |  | 1360h |
| 54 | 1.2.1 | **Design/Build Stage** | 98.89d | 2007-01-01 A | 2007-05-17 |  | 3% | 95.7d | 389.14d |  |  | 1360h |
| 55 | 1.2.1.1 | **Business/Process Track** | 98.89d | 2007-01-01 | 2007-05-17 |  |  |  | 389.14d |  |  |  |
| 56 | 1.2.1.1.1 | **Process Analysis** | 98.89d | 2007-01-01 | 2007-05-17 |  |  |  | 389.14d |  |  |  |
| 57 | 1.2.1.1.1.1 | **Develop Process Maps** | 25d | 2007-01-01 | 2007-02-02 |  |  |  | 389.14d |  |  |  |
| 58 | 1.2.1.1.1.1.1 | Data Collection | 10d | 2007-01-01 | 2007-01-12 |  |  |  | 389.14d | 0d |  |  |
| 59 | 1.2.1.1.1.1.2 | Modify/create "as is" process map | 5d | 2007-01-15 | 2007-01-19 | 58 |  |  | 389.14d | 0d |  |  |
| 60 | 1.2.1.1.1.1.3 | Align with Org. chg Management | 10d | 2007-01-22 | 2007-02-02 | 59 |  |  | 389.14d | 0d |  |  |
| 61 | 1.2.1.1.1.2 | Create Management Processes | 3d | 2007-02-05 | 2007-02-08 | 60 |  |  | 389.14d | 0d |  |  |
| 62 | 1.2.1.1.1.3 | Create Support Processes | 3d | 2007-02-08 | 2007-02-13 | 61 |  |  | 389.14d | 0d |  |  |
| 63 | 1.2.1.1.1.4 | Job Level Process Maps - Collections | 9d | 2007-02-13 | 2007-03-02 | 62 |  |  | 389.14d | 0d |  |  |
| 64 | 1.2.1.1.1.5 | Job Level Process Maps - Cancellations and Express Post | 3d | 2007-03-02 | 2007-03-07 | 63 |  |  | 389.14d | 0d |  |  |
| 65 | 1.2.1.1.1.6 | Revise Process Maps | 6.25d | 2007-03-07 | 2007-03-15 | 64 |  |  | 389.14d | 0d |  |  |
| 66 | 1.2.1.1.1.7 | Revise Business Rules | 5d | 2007-03-15 | 2007-03-26 | 65 |  |  | 389.14d | 0d |  |  |
| 67 | 1.2.1.1.1.8 | Revise Plan as required/Obtain Approval on Major Changes | 2d | 2007-03-26 | 2007-03-28 | 66 |  |  | 389.14d | 0d |  |  |
| 68 | 1.2.1.1.1.9 | Process GAP Document from Current Environment - Org. Rollout | 12.5d | 2007-03-28 | 2007-04-16 | 67 |  |  | 389.14d | 0d |  |  |
| 69 | 1.2.1.1.1.10 | **Service Level Agreements** | 22.37d | 2007-04-16 | 2007-05-16 | 68 |  |  | 389.14d |  |  |  |
| 70 | 1.2.1.1.1.10.1 | HO/regional center | 1.77d | 2007-04-16 | 2007-04-23 |  |  |  | 389.14d | 0d | start no earlier than 2001-10-15 |  |
| 71 | 1.2.1.1.1.10.2 | regional centre/branch | 1.77d | 2007-04-23 | 2007-04-30 | 70 |  |  | 389.14d | 0d | start no earlier than 2001-10-15 |  |
| 72 | 1.2.1.1.1.10.3 | broker/regional centre | 1.77d | 2007-04-30 | 2007-05-07 | 71 |  |  | 389.14d | 0d | start no earlier than 2001-10-15 |  |
| 73 | 1.2.1.1.1.10.4 | Personal/Commercial and Finance | 1.77d | 2007-05-07 | 2007-05-16 | 72 |  |  | 389.14d | 0d |  |  |
| 74 | 1.2.1.1.1.11 | **Client Service Standards** | 1.15d | 2007-05-16 | 2007-05-17 | 73 |  |  | 389.14d |  |  |  |
| 75 | 1.2.1.1.1.11.1 | Review Existing | 0.35d | 2007-05-16 | 2007-05-17 |  |  |  | 389.14d | 0d |  |  |
| 76 | 1.2.1.1.1.11.2 | Modify Existing | 0.35d | 2007-05-17 | 2007-05-17 | 75 |  |  | 389.14d |  |  |  |

| ID | WBS | Task | Duration | Start | Finish | Predecessors | Total slack | Free slack |
| --- | --- | --- | --- | --- | --- | --- | --- | --- |
| 77 | 1.2.1.1.2 | **Solution Design, Build and Test** | 64.48d | 2007-01-01 | 2007-03-30 |  | 423.56d |  |
| 78 | 1.2.1.1.2.1 | **Detailed Design/Activities For:** | 64.48d | 2007-01-01 | 2007-03-30 |  | 423.56d |  |
| 79 | 1.2.1.1.2.1.1 | **Functional Design** | 3.61d | 2007-03-26 | 2007-03-30 |  | 423.56d |  |
| 80 | 1.2.1.1.2.1.1.1 | **Develop Use Cases** | 3.61d | 2007-03-26 | 2007-03-30 |  | 423.56d |  |
| 81 | 1.2.1.1.2.1.1.1.1 | Centralize Deposits and Receipts | 0.7d | 2007-03-26 | 2007-03-28 | 66 | 423.56d | 0d |
| 82 | 1.2.1.1.2.1.1.1.2 | Centralize Remittances | 0.7d | 2007-03-28 | 2007-03-29 | 81 | 423.56d | 0d |
| 83 | 1.2.1.1.2.1.1.1.3 | Centralize Premium Refunds | 0.7d | 2007-03-29 | 2007-03-30 | 82 | 423.56d |  |
| 84 | 1.2.1.1.2.1.2 | **Centralize Deposits and Receipts** | 0.13d | 2007-01-01 | 2007-01-01 |  | 485.34d |  |
| 85 | 1.2.1.1.2.1.2.1 | Rollout Schedule | 0.13d | 2007-01-01 | 2007-01-01 |  | 485.34d | 0d |
| 86 | 1.2.1.1.2.1.3 | **Centralize Remittances** | 0.15d | 2007-01-01 | 2007-01-01 |  | 485.34d |  |
| 87 | 1.2.1.1.2.1.3.1 | Rollout Schedule | 0.15d | 2007-01-01 | 2007-01-01 | 85 | 485.34d | 0d |
| 88 | 1.2.1.1.2.1.4 | **Centralize Premium Refunds** | 0.15d | 2007-01-01 | 2007-01-01 |  | 485.34d |  |
| 89 | 1.2.1.1.2.1.4.1 | Rollout Schedule | 0.15d | 2007-01-01 | 2007-01-01 | 87 | 485.34d | 0d |
| 90 | 1.2.1.1.2.1.5 | **Cancellation, Write-off and Collection** | 0.27d | 2007-01-01 | 2007-01-01 |  | 485.34d |  |
| 91 | 1.2.1.1.2.1.5.1 | Confirm Pilot | 0.13d | 2007-01-01 | 2007-01-01 | 89 | 485.34d | 0d |
| 92 | 1.2.1.1.2.1.5.2 | Rollout Schedule | 0.13d | 2007-01-01 | 2007-01-01 | 91 | 485.34d | 0d |
| 93 | 1.2.1.1.2.1.6 | **Forms Design** | 2d | 2007-01-01 | 2007-01-03 |  | 485.34d |  |
| 94 | 1.2.1.1.2.1.6.1 | Investigate Forms | 1d | 2007-01-01 | 2007-01-02 | 92 | 485.34d | 0d |
| 95 | 1.2.1.1.2.1.6.2 | **Create Forms** | 1d | 2007-01-02 | 2007-01-03 | 94 | 485.34d |  |
| 96 | 1.2.1.1.2.1.6.2.1 | …. | 1d | 2007-01-02 | 2007-01-03 |  | 745.14d |  |
| 97 | 1.2.1.1.3 | **Cutover Planning** | 3.5d | 2007-01-01 | 2007-01-04 |  | 484.53d |  |
| 98 | 1.2.1.1.3.1 | **Prepare Cutover Task Plans** | 2.81d | 2007-01-01 | 2007-01-03 |  | 485.23d |  |
| 99 | 1.2.1.1.3.1.1 | Develop Detail Cutover Approach/Strategy | 0.42d | 2007-01-01 | 2007-01-01 |  | 745.03d | 0d |
| 100 | 1.2.1.1.3.1.2 | Develop details for support models | 0.42d | 2007-01-01 | 2007-01-01 | 99 | 745.03d | 0d |
| 101 | 1.2.1.1.3.1.3 | Compile/refine contingency plan | 0.42d | 2007-01-01 | 2007-01-02 | 100 | 745.03d | 0d |
| 102 | 1.2.1.1.3.1.4 | Obtain Approval of Strategy and Plan | 0.56d | 2007-01-02 | 2007-01-02 | 101 | 745.03d | 0d |
| 103 | 1.2.1.1.3.1.5 | Integrate cutover timeline with project plan | 1d | 2007-01-02 | 2007-01-03 | 102 | 745.03d |  |

| ID | WBS | Task | Duration | Start | Finish | Predecessors | Complete | Remaining | Total slack | Free slack | Work |
| --- | --- | --- | --- | --- | --- | --- | --- | --- | --- | --- | --- |
| 104 | 1.2.1.1.3.2 | **Prepare for Final Environment** | 3.5d | 2007-01-01 | 2007-01-04 |  |  |  | 484.53d |  |  |
| 105 | 1.2.1.1.3.2.1 | Confirm readiness of legacy changes | 1.25d | 2007-01-01 | 2007-01-02 |  |  |  | 744.33d | 0d |  |
| 106 | 1.2.1.1.3.2.2 | Confirm Service Level Agreements are in place | 1.25d | 2007-01-02 | 2007-01-03 | 105 |  |  | 744.33d | 0d |  |
| 107 | 1.2.1.1.3.2.3 | Confirm availability of facilities | 0.5d | 2007-01-03 | 2007-01-03 | 106 |  |  | 744.33d | 0d |  |
| 108 | 1.2.1.1.3.2.4 | Confirm operational processes are in place for production environment | 0.5d | 2007-01-04 | 2007-01-04 | 107 |  |  | 744.33d |  |  |
| 109 | 1.2.1.1.4 | **Security and Controls** | 1.11d | 2007-01-01 | 2007-01-02 |  |  |  | 486.92d |  |  |
| 110 | 1.2.1.1.4.1 | Determine Security Changes | 0.56d | 2007-01-01 | 2007-01-01 |  |  |  | 486.92d | 0d |  |
| 111 | 1.2.1.1.4.2 | Completed Security Change Forms | 0.56d | 2007-01-01 | 2007-01-02 | 110 |  |  | 486.92d |  |  |
| 112 | 1.2.1.2 | **Change Management Track** | 60d | 2007-01-01 A | 2007-03-23 |  | 4% | 57.41d | 428.03d |  | 1360h |
| 113 | 1.2.1.2.1 | **Immediate Recruiting Needs** | 40d | 2007-01-01 | 2007-02-23 |  |  |  | 448.03d |  |  |
| 114 | 1.2.1.2.1.1 | Recruit Operations Manager | 40d | 2007-01-01 | 2007-02-23 |  |  |  | 448.03d |  |  |
| 115 | 1.2.1.2.2 | **Develop Change Strategy** | 10d | 2007-01-01 A | 2007-01-12 |  | 25% | 7.54d | 478.03d |  |  |
| 116 | 1.2.1.2.2.1 | **Project Team Effectiveness and Mobilization** | 10d | 2007-01-01 | 2007-01-12 |  |  |  | 478.03d |  |  |
| 117 | 1.2.1.2.2.1.1 | **Mobilize project team** | 10d | 2007-01-01 | 2007-01-12 |  |  |  | 478.03d |  |  |
| 118 | 1.2.1.2.2.1.1.1 | Confirm Project Team structure, roles and responsibilities | 1d | 2007-01-01 | 2007-01-01 |  |  |  | 746.83d |  |  |
| 119 | 1.2.1.2.2.1.1.2 | Obtain approval from Steering Community on Role, Responsibility, level of effort and Membership | 1d | 2007-01-01 | 2007-01-01 |  |  |  | 746.83d |  |  |
| 120 | 1.2.1.2.2.1.1.3 | One on One Meetings - Roles and Resp | 10d | 2007-01-01 | 2007-01-12 |  |  |  | 737.83d |  |  |
| 121 | 1.2.1.2.2.1.1.4 | Confirm Case for Change - Benefits | 1d | 2007-01-01 | 2007-01-01 |  |  |  | 746.83d |  |  |
| 122 | 1.2.1.2.2.1.1.5 | Project Charter - Scope, Approach, Schedules, Resources | 1d | 2007-01-01 | 2007-01-01 |  |  |  | 746.83d |  |  |
| 123 | 1.2.1.2.2.1.1.6 | Develop and Deliver Team Building and Change Leadership Session? | 1d | 2007-01-01 | 2007-01-01 |  |  |  | 746.83d |  |  |
| 124 | 1.2.1.2.2.1.1.7 | Kick-off Meeting | 1d | 2007-01-01 | 2007-01-01 |  |  |  | 746.83d |  |  |
| 125 | 1.2.1.2.2.1.2 | Team Retention Strategy | 1d | 2007-01-01 | 2007-01-01 |  |  |  | 487.03d |  |  |
| 126 | 1.2.1.2.2.1.3 | Examine overall process (corporate) for project team performance metrics | 1d | 2007-01-01 | 2007-01-01 |  |  |  | 487.03d |  |  |
| 127 | 1.2.1.2.2.1.4 | Define individual <client> team member's performance objectives | 1d | 2007-01-01 | 2007-01-01 |  |  |  | 487.03d |  |  |
| 128 | 1.2.1.2.2.1.5 | Develop performance metrics for team | 1d | 2007-01-01 | 2007-01-01 |  |  |  | 487.03d |  |  |

| ID | WBS | Task | Duration | Start | Finish | Complete | Remaining | Total slack |
| --- | --- | --- | --- | --- | --- | --- | --- | --- |
| 129 | 1.2.1.2.2.2 | **Assess Change Readiness - <client> OR CORPORATE O/S DECISION** | 1d | 2007-01-01 | 2007-01-01 |  |  | 487.03d |
| 130 | 1.2.1.2.2.2.1 | Identify areas for assessment and discuss possible road map | 1d | 2007-01-01 | 2007-01-01 |  |  | 487.03d |
| 131 | 1.2.1.2.2.2.2 | Develop assessment plans and tools | 1d | 2007-01-01 | 2007-01-01 |  |  | 487.03d |
| 132 | 1.2.1.2.2.2.3 | Conduct Stakeholder analysis | 1d | 2007-01-01 | 2007-01-01 |  |  | 487.03d |
| 133 | 1.2.1.2.2.2.4 | Document Findings | 1d | 2007-01-01 | 2007-01-01 |  |  | 487.03d |
| 134 | 1.2.1.2.2.2.5 | Present to Stakeholders | 1d | 2007-01-01 | 2007-01-01 |  |  | 487.03d |
| 135 | 1.2.1.2.2.2.6 | Identify Change Challenges | 1d | 2007-01-01 | 2007-01-01 |  |  | 487.03d |
| 136 | 1.2.1.2.2.2.7 | Identify Change Critical Success Criteria | 1d | 2007-01-01 | 2007-01-01 |  |  | 487.03d |
| 137 | 1.2.1.2.2.2.8 | Revise Change Plan | 1d | 2007-01-01 | 2007-01-01 |  |  | 487.03d |
| 138 | 1.2.1.2.2.3 | **Develop Stakeholder Engagement Strategies** | 1.67d | 2007-01-01 A | 2007-01-02 | 42% | 0.96d | 486.37d |
| 139 | 1.2.1.2.2.3.1 | Identify and Segment Key Stakeholders | 1d | 2007-01-01 A | 2007-01-01 A | 100% |  |  |
| 140 | 1.2.1.2.2.3.2 | Analyze Stakeholder Environment, Readiness for Change | 1d | 2007-01-01 A | 2007-01-01 A | 100% |  |  |
| 141 | 1.2.1.2.2.3.3 | Map Stakeholders and Complete Initial Assessment | 1d | 2007-01-01 A | 2007-01-01 A | 100% |  |  |
| 142 | 1.2.1.2.2.3.4 | **Define Strategies** | 1.67d | 2007-01-01 A | 2007-01-02 | 23% | 1.29d | 486.37d |
| 143 | 1.2.1.2.2.3.4.1 | Define Engagement Strategies | 1d | 2007-01-01 A | 2007-01-01 A | 100% |  |  |
| 144 | 1.2.1.2.2.3.4.2 | Align with Communication Plan | 1.67d | 2007-01-01 | 2007-01-02 |  |  | 486.37d |
| 145 | 1.2.1.2.2.3.4.3 | Identify Specific Tactics | 1d | 2007-01-01 A | 2007-01-01 | 50% | 0.5d | 487.03d |
| 146 | 1.2.1.2.2.3.4.4 | Validate with Steering Committee | 1d | 2007-01-01 | 2007-01-01 |  |  | 487.03d |
| 147 | 1.2.1.2.2.3.4.5 | Validate with Branch Mgr | 1d | 2007-01-01 | 2007-01-01 |  |  | 487.03d |
| 148 | 1.2.1.2.2.3.4.6 | Present to Project Team, Finance, Affected Staff | 1d | 2007-01-01 | 2007-01-01 |  |  | 487.03d |
| 149 | 1.2.1.2.2.3.5 | Obtain Approval | 1d | 2007-01-01 | 2007-01-01 |  |  | 487.03d |
| 150 | 1.2.1.2.2.4 | **Conduct preliminary org. impact assessment - based on new processes** | 1.67d | 2007-01-01 A | 2007-01-02 | 63% | 0.62d | 486.37d |
| 151 | 1.2.1.2.2.4.1 | Assess current Org. Structure | 1d | 2007-01-01 A | 2007-01-01 A | 100% |  |  |
| 152 | 1.2.1.2.2.4.2 | Document Preliminary Org. Impacts | 1.67d | 2007-01-01 A | 2007-01-02 | 30% | 1.17d | 486.37d |
| 153 | 1.2.1.2.2.4.3 | Develop High-Level Strategies to Address Impacts | 1.67d | 2007-01-01 | 2007-01-02 |  |  | 486.37d |
| 154 | 1.2.1.2.2.4.4 | Obtain Approval | 1d | 2007-01-01 | 2007-01-01 |  |  | 487.03d |

| ID | WBS | Task | Duration | Start | Finish | Complete | Remaining | Total slack | Constraint |
| --- | --- | --- | --- | --- | --- | --- | --- | --- | --- |
| 155 | 1.2.1.2.2.4.5 | **Develop Org. Design Principles** | 1d | 2007-01-01 A | 2007-01-01 A | 100% |  |  |  |
| 156 | 1.2.1.2.2.4.5.1 | Document Business Drivers | 1d | 2007-01-01 A | 2007-01-01 A | 100% |  |  |  |
| 157 | 1.2.1.2.2.4.5.2 | Identify Best Practices | 1d | 2007-01-01 A | 2007-01-01 A | 100% |  |  |  |
| 158 | 1.2.1.2.2.4.5.3 | Identify Principles | 1d | 2007-01-01 A | 2007-01-01 A | 100% |  |  |  |
| 159 | 1.2.1.2.2.4.6 | Strategic Level - Organization Structure/Design Options | 1d | 2007-01-01 A | 2007-01-01 A | 100% |  |  |  |
| 160 | 1.2.1.2.2.4.7 | Recommend and Obtain Approval on Option | 1d | 2007-01-01 A | 2007-01-01 | 99% | 0.01d | 487.03d |  |
| 161 | 1.2.1.2.2.5 | **Communication Strategy/Plan** | 2.5d | 2007-01-01 A | 2007-01-03 | 16% | 2.1d | 485.53d |  |
| 162 | 1.2.1.2.2.5.1 | Review existing communication program for all projects | 2.5d | 2007-01-01 A | 2007-01-03 | 30% | 1.75d | 485.53d |  |
| 163 | 1.2.1.2.2.5.2 | Confirm Change Messages and Target Audience | 2.5d | 2007-01-01 A | 2007-01-03 | 20% | 2d | 485.53d |  |
| 164 | 1.2.1.2.2.5.3 | Establish Communication Vehicles | 2.5d | 2007-01-01 A | 2007-01-03 | 20% | 2d | 485.53d |  |
| 165 | 1.2.1.2.2.5.4 | Revise Existing Communication Templates | 2.5d | 2007-01-01 A | 2007-01-03 | 20% | 2d | 485.53d |  |
| 166 | 1.2.1.2.2.5.5 | Develop detailed Communication Plan and time-phased activities | 1.17d | 2007-01-01 A | 2007-01-02 | 43% | 0.67d | 486.87d |  |
| 167 | 1.2.1.2.2.5.6 | Establish Feedback/ Monitoring Mechanisms | 1d | 2007-01-01 | 2007-01-01 |  |  | 487.03d |  |
| 168 | 1.2.1.2.2.5.7 | Adjust Strategy/Plan for <dept> | 1.11d | 2007-01-01 | 2007-01-02 |  |  | 486.92d |  |
| 169 | 1.2.1.2.2.5.8 | Obtain Approval | 1d | 2007-01-01 | 2007-01-01 |  |  | 487.03d |  |
| 170 | 1.2.1.2.2.5.9 | **Marketing Literature - Coordination** | 1d | 2007-01-01 | 2007-01-01 |  |  | 487.03d |  |
| 171 | 1.2.1.2.2.5.9.1 | Broker Profile | 0.89d | 2007-01-01 | 2007-01-01 |  |  | 487.14d |  |
| 172 | 1.2.1.2.2.5.9.2 | Payment Matrix | 0.83d | 2007-01-01 | 2007-01-01 |  |  | 487.2d |  |
| 173 | 1.2.1.2.2.5.9.3 | Obtain Approval | 1d | 2007-01-01 | 2007-01-01 |  |  | 487.03d |  |
| 174 | 1.2.1.2.2.6 | **High-Level Training Strategy** | 1.25d | 2007-01-01 A | 2007-01-02 | 64% | 0.45d | 486.78d |  |
| 175 | 1.2.1.2.2.6.1 | Assess Existing Training Structure | 1d | 2007-01-01 A | 2007-01-01 | 80% | 0.2d | 487.03d |  |
| 176 | 1.2.1.2.2.6.2 | Determine capacity for effective delivery | 1d | 2007-01-01 A | 2007-01-01 | 80% | 0.2d | 487.03d |  |
| 177 | 1.2.1.2.2.6.3 | Identify Lessons Learned | 1d | 2007-01-01 A | 2007-01-01 | 80% | 0.2d | 487.03d |  |
| 178 | 1.2.1.2.2.6.4 | Develop Principles | 1d | 2007-01-01 A | 2007-01-01 | 80% | 0.2d | 487.03d |  |
| 179 | 1.2.1.2.2.6.5 | Identify User Communities | 1d | 2007-01-01 A | 2007-01-01 | 80% | 0.2d | 487.03d |  |
| 180 | 1.2.1.2.2.6.6 | Validate with Team | 1.25d | 2007-01-01 | 2007-01-02 |  |  | 486.78d | start no earlier than 2007-01-01 |

| ID | WBS | Task | Duration | Start | Finish | Total slack | Work |
| --- | --- | --- | --- | --- | --- | --- | --- |
| 181 | 1.2.1.2.3 | **Project Team Training** | 2d | 2007-01-01 | 2007-01-02 | 486.03d |  |
| 182 | 1.2.1.2.3.1 | **Plan Project Team Training** | 2d | 2007-01-01 | 2007-01-02 | 486.03d |  |
| 183 | 1.2.1.2.3.1.1 | Develop team training plan | 2d | 2007-01-01 | 2007-01-02 | 745.83d |  |
| 184 | 1.2.1.2.3.2 | **Complete Core Project Team Training** | 1d | 2007-01-01 | 2007-01-01 | 487.03d |  |
| 185 | 1.2.1.2.3.2.1 | Methodology and life cycle training | 1d | 2007-01-01 | 2007-01-01 | 746.83d |  |
| 186 | 1.2.1.2.3.2.2 | **Application training** | 1d | 2007-01-01 | 2007-01-01 | 487.03d |  |
| 187 | 1.2.1.2.3.2.2.1 | Accounts Receivable | 1d | 2007-01-01 | 2007-01-01 | 746.83d |  |
| 188 | 1.2.1.2.3.2.2.2 | Non-Technical Training (TDB) | 1d | 2007-01-01 | 2007-01-01 | 746.83d |  |
| 189 | 1.2.1.2.4 | **Manage the Change** | 60d | 2007-01-01 | 2007-03-23 | 428.03d | 1360h |
| 190 | 1.2.1.2.4.1 | **Knowledge Management** | 40d | 2007-01-01 | 2007-02-23 | 448.03d |  |
| 191 | 1.2.1.2.4.1.1 | Recruit Operations Manager | 40d | 2007-01-01 | 2007-02-23 | 707.83d |  |
| 192 | 1.2.1.2.4.1.2 | Explore Knowledge Management Framework | 1.5d | 2007-01-01 | 2007-01-02 | 746.33d |  |
| 193 | 1.2.1.2.4.1.3 | …. | 1d | 2007-01-01 | 2007-01-01 | 746.83d |  |
| 194 | 1.2.1.2.4.2 | **Implement Stakeholder Engagement Strategies** | 1d | 2007-01-01 | 2007-01-01 | 487.03d |  |
| 195 | 1.2.1.2.4.2.1 | Ongoing - Develop & maintain network of Change Agents (incl. <dept>) | 1d | 2007-01-01 | 2007-01-01 | 746.83d |  |
| 196 | 1.2.1.2.4.2.2 | Ongoing - Monitor and Revise stakeholder mgmt strategy as required | 1d | 2007-01-01 | 2007-01-01 | 746.83d |  |
| 197 | 1.2.1.2.4.2.3 | Ongoing - Change Mgmt Workshops | 1d | 2007-01-01 | 2007-01-01 | 746.83d |  |
| 198 | 1.2.1.2.4.3 | **Complete Organization Design** | 10d | 2007-01-01 | 2007-01-12 | 478.03d |  |
| 199 | 1.2.1.2.4.3.1 | **Develop Unit-Level Structures** | 10d | 2007-01-01 | 2007-01-12 | 478.03d |  |
| 200 | 1.2.1.2.4.3.1.1 | Validate "to be" workflows | 2.5d | 2007-01-01 | 2007-01-03 | 745.33d |  |
| 201 | 1.2.1.2.4.3.1.2 | Define and Develop Unit Level Roles | 10d | 2007-01-01 | 2007-01-12 | 737.83d |  |
| 202 | 1.2.1.2.4.3.1.3 | Confirm Process Responsibilities and Accountability | 2d | 2007-01-01 | 2007-01-02 | 745.83d |  |
| 203 | 1.2.1.2.4.3.1.4 | Preliminary Performance Measures | 2d | 2007-01-01 | 2007-01-02 | 745.83d |  |
| 204 | 1.2.1.2.4.3.1.5 | Develop Competencies and Position Descriptions (PDQs) | 5d | 2007-01-01 | 2007-01-05 | 742.83d |  |
| 205 | 1.2.1.2.4.3.1.6 | Define skill gaps & additional training needs | 2.5d | 2007-01-01 | 2007-01-03 | 745.33d |  |
| 206 | 1.2.1.2.4.3.1.7 | Validate with Team and Steering Committee | 1d | 2007-01-01 | 2007-01-01 | 746.83d |  |
| 207 | 1.2.1.2.4.3.1.8 | Obtain Approval | 1d | 2007-01-01 | 2007-01-01 | 746.83d |  |

| ID | WBS | Task | Type | Duration | Start | Finish | Predecessors | Total slack | Free slack |
| --- | --- | --- | --- | --- | --- | --- | --- | --- | --- |
| 208 | 1.2.1.2.4.3.1.9 | **After Completion of CRP2 - Target Processes Finalized** |  | 5d | 2007-01-01 | 2007-01-05 |  | 483.03d |  |
| 209 | 1.2.1.2.4.3.1.9.1 | Revise based on completed target processes from CRP2 |  | 5d | 2007-01-01 | 2007-01-05 |  | 742.83d |  |
| 210 | 1.2.1.2.4.3.1.9.2 | Revise PDQs as required |  | 1d | 2007-01-01 | 2007-01-01 |  | 746.83d |  |
| 211 | 1.2.1.2.4.3.1.10 | Obtain Approval |  | 1d | 2007-01-01 | 2007-01-01 |  | 745.83d | 0d |
| 212 | 1.2.1.2.4.3.2 | **HR Policy Amendments** |  | 1d | 2007-01-02 | 2007-01-02 | 211 | 486.03d |  |
| 213 | 1.2.1.2.4.3.2.1 | Review HR Policies |  | 1d | 2007-01-02 | 2007-01-02 |  | 745.83d |  |
| 214 | 1.2.1.2.4.3.2.2 | Identify Impacts and Changes Required |  | 1d | 2007-01-02 | 2007-01-02 |  | 745.83d |  |
| 215 | 1.2.1.2.4.3.2.3 | Examine Career Management Issues, Paths |  | 1d | 2007-01-02 | 2007-01-02 |  | 745.83d |  |
| 216 | 1.2.1.2.4.3.2.4 | Validate Changes and Obtain Approval |  | 1d | 2007-01-02 | 2007-01-02 |  | 745.83d |  |
| 217 | 1.2.1.2.4.3.2.5 | **Align Performance Mgmt Systems** |  | 1d | 2007-01-02 | 2007-01-02 |  | 486.03d |  |
| 218 | 1.2.1.2.4.3.2.5.1 | Review Current Perf. Mgmt Systems |  | 1d | 2007-01-02 | 2007-01-02 |  | 745.83d |  |
| 219 | 1.2.1.2.4.3.2.5.2 | Determine GAPs |  | 1d | 2007-01-02 | 2007-01-02 |  | 745.83d |  |
| 220 | 1.2.1.2.4.3.2.5.3 | Determine Alignment Strategies |  | 1d | 2007-01-02 | 2007-01-02 |  | 745.83d |  |
| 221 | 1.2.1.2.4.3.3 | **Compensation Design** |  | 8d | 2007-01-01 | 2007-01-10 |  | 480.03d |  |
| 222 | 1.2.1.2.4.3.3.1 | Conduct Job Evaluations |  | 8d | 2007-01-01 | 2007-01-10 |  | 739.83d |  |
| 223 | 1.2.1.2.4.3.3.2 | Benchmark to External Sources |  | 1d | 2007-01-01 | 2007-01-01 |  | 746.83d |  |
| 224 | 1.2.1.2.4.3.3.3 | Develop and Review Corporate Framework and Principles |  | 2d | 2007-01-01 | 2007-01-02 |  | 745.83d |  |
| 225 | 1.2.1.2.4.3.3.4 | Define Compensation Strategy |  | 3d | 2007-01-01 | 2007-01-03 |  | 744.83d |  |
| 226 | 1.2.1.2.4.3.3.5 | Obtain Approval |  | 1d | 2007-01-01 | 2007-01-01 |  | 746.83d |  |
| 227 | 1.2.1.2.4.3.3.6 | Implement Changes - Ongoing | milestone | 0d | 2007-01-01 | 2007-01-01 |  | 747.83d |  |
| 228 | 1.2.1.2.4.3.4 | **Recruitment Strategy** |  | 5d | 2007-01-01 | 2007-01-05 |  | 483.03d |  |
| 229 | 1.2.1.2.4.3.4.1 | Develop Strategy |  | 5d | 2007-01-01 | 2007-01-05 |  | 742.83d |  |
| 230 | 1.2.1.2.4.3.4.2 | Implement Strategy - Ongoing (avg. days for recruiting?) |  | 1d | 2007-01-01 | 2007-01-01 |  | 746.83d |  |
| 231 | 1.2.1.2.4.3.5 | **Staff Retention/Redeployment, Transition and Migration** |  | 5d | 2007-01-01 | 2007-01-05 |  | 483.03d |  |
| 232 | 1.2.1.2.4.3.5.1 | Determine and confirm positions by region |  | 0.95d | 2007-01-01 | 2007-01-01 |  | 746.88d |  |

| ID | WBS | Task | Duration | Start | Finish | Total slack | Work |
| --- | --- | --- | --- | --- | --- | --- | --- |
| 233 | 1.2.1.2.4.3.5.2 | **Develop Migration Strategy** | 1.43d | 2007-01-01 | 2007-01-02 | 486.61d |  |
| 234 | 1.2.1.2.4.3.5.2.1 | Timing | 1.43d | 2007-01-01 | 2007-01-02 | 746.41d |  |
| 235 | 1.2.1.2.4.3.5.2.2 | Principles | 1.43d | 2007-01-01 | 2007-01-02 | 746.41d |  |
| 236 | 1.2.1.2.4.3.5.2.3 | Policies | 1.43d | 2007-01-01 | 2007-01-02 | 746.41d |  |
| 237 | 1.2.1.2.4.3.5.2.4 | Adjustment Measures | 1.43d | 2007-01-01 | 2007-01-02 | 746.41d |  |
| 238 | 1.2.1.2.4.3.5.2.5 | Recruitment/Support | 1.43d | 2007-01-01 | 2007-01-02 | 746.41d |  |
| 239 | 1.2.1.2.4.3.5.3 | Confirm Strategy | 1d | 2007-01-01 | 2007-01-01 | 746.83d |  |
| 240 | 1.2.1.2.4.3.5.4 | Validation with Key Staff and Incorporate Feedback | 2d | 2007-01-01 | 2007-01-02 | 745.83d |  |
| 241 | 1.2.1.2.4.3.5.5 | Obtain Approval on Strategy | 1d | 2007-01-01 | 2007-01-01 | 746.83d |  |
| 242 | 1.2.1.2.4.3.5.6 | Discuss Transition Options with All Affected Staff | 5d | 2007-01-01 | 2007-01-05 | 742.83d |  |
| 243 | 1.2.1.2.4.3.5.7 | Provide Support to Staff and Managers | 5d | 2007-01-01 | 2007-01-05 | 742.83d |  |
| 244 | 1.2.1.2.4.4 | **Implement Communication Strategy and Plan** | 60d | 2007-01-01 | 2007-03-23 | 428.03d | 1360h |
| 245 | 1.2.1.2.4.4.1 | Newsletters - 6 | 60d | 2007-01-01 | 2007-03-23 | 687.83d |  |
| 246 | 1.2.1.2.4.4.2 | **Sample - Tasks/Estimates** | 1d | 2007-01-01 | 2007-01-01 | 487.03d | 160h |
| 247 | 1.2.1.2.4.4.2.1 | Drafting of Articles and Approval | 1d | 2007-01-01 | 2007-01-01 | 746.83d | 36h |
| 248 | 1.2.1.2.4.4.2.2 | Memo to Branch Managers | 1d | 2007-01-01 | 2007-01-01 | 746.83d |  |
| 249 | 1.2.1.2.4.4.2.3 | English - Layout, production and distribution | 1d | 2007-01-01 | 2007-01-01 | 746.83d | 56h |
| 250 | 1.2.1.2.4.4.2.4 | English - Newsletter on Employees Desk | 1d | 2007-01-01 | 2007-01-01 | 746.83d |  |
| 251 | 1.2.1.2.4.4.2.5 | Translate to French | 1d | 2007-01-01 | 2007-01-01 | 746.83d | 24h |
| 252 | 1.2.1.2.4.4.2.6 | French - Layout, Production and Distribution | 1d | 2007-01-01 | 2007-01-01 | 746.83d | 40h |
| 253 | 1.2.1.2.4.4.2.7 | French - Newsletter on Employees Desk | 1d | 2007-01-01 | 2007-01-01 | 746.83d |  |
| 254 | 1.2.1.2.4.4.2.8 | Assess Feedback | 1d | 2007-01-01 | 2007-01-01 | 746.83d | 4h |
| 255 | 1.2.1.2.4.4.3 | Fact Sheets - By Milestones | 1d | 2007-01-01 | 2007-01-01 | 746.83d | 240h |
| 256 | 1.2.1.2.4.4.4 | E-mails/Voice-Mails | 1d | 2007-01-01 | 2007-01-01 | 746.83d | 240h |
| 257 | 1.2.1.2.4.4.5 | Ongoing unscheduled communication activities (includes <dept>) | 1d | 2007-01-01 | 2007-01-01 | 746.83d | 320h |
| 258 | 1.2.1.2.4.4.6 | Coaching to Mgmt to Support Staff Communications | 1d | 2007-01-01 | 2007-01-01 | 746.83d | 160h |
| 259 | 1.2.1.2.4.4.7 | Formal Information Sessions | 1d | 2007-01-01 | 2007-01-01 | 746.83d | 80h |
| 260 | 1.2.1.2.4.4.8 | Assess Feedback - Ongoing | 1d | 2007-01-01 | 2007-01-01 | 746.83d | 160h |

| ID | WBS | Task | Duration | Start | Finish | Total slack |
| --- | --- | --- | --- | --- | --- | --- |
| 261 | 1.2.1.2.4.5 | **Ongoing - Change Mgmt Project Team Monitoring & Reporting Tasks** | 1d | 2007-01-01 | 2007-01-01 | 487.03d |
| 262 | 1.2.1.2.4.5.1 | Lessons Learned - after every Major Milestones | 1d | 2007-01-01 | 2007-01-01 | 746.83d |
| 263 | 1.2.1.2.4.5.2 | Lessons Learned - after every Major Milestones | 1d | 2007-01-01 | 2007-01-01 | 746.83d |
| 264 | 1.2.1.2.4.5.3 | Lessons Learned - after every Major Milestones | 1d | 2007-01-01 | 2007-01-01 | 746.83d |
| 265 | 1.2.1.2.4.5.4 | Lessons Learned - after every Major Milestones | 1d | 2007-01-01 | 2007-01-01 | 746.83d |
| 266 | 1.2.1.2.4.5.5 | Communicate and monitor team member change mgmt tasks | 1d | 2007-01-01 | 2007-01-01 | 746.83d |
| 267 | 1.2.1.2.4.5.6 | Monitor Project Effectiveness | 1d | 2007-01-01 | 2007-01-01 | 746.83d |
| 268 | 1.2.1.2.4.5.7 | Ongoing coaching to project team, extended team, management | 1d | 2007-01-01 | 2007-01-01 | 746.83d |
| 269 | 1.2.1.2.4.5.8 | Monitor Effectiveness of Change | 1d | 2007-01-01 | 2007-01-01 | 746.83d |
| 270 | 1.2.1.2.4.5.9 | Track & communicate people & org issues | 0.55d | 2007-01-01 | 2007-01-01 | 747.29d |
| 271 | 1.2.1.2.4.5.10 | Monitor Decision Making process | 1d | 2007-01-01 | 2007-01-01 | 746.83d |
| 272 | 1.2.1.2.4.6 | **Sustainment Readiness** | 10d | 2007-01-01 | 2007-01-12 | 478.03d |
| 273 | 1.2.1.2.4.6.1 | Define re-entry strategy for <client> Team | 3d | 2007-01-01 | 2007-01-03 | 744.83d |
| 274 | 1.2.1.2.4.6.2 | Confirm Understanding of roles, responsibilities, workflow, decision mkg, technology, etc. | 10d | 2007-01-01 | 2007-01-12 | 737.83d |
| 275 | 1.2.1.2.4.6.3 | Develop ongoing post implementation evaluation plan and mechanisms | 2d | 2007-01-01 | 2007-01-02 | 745.83d |
| 276 | 1.2.1.2.5 | **User Procedures and Training** | 24d | 2007-01-01 | 2007-02-01 | 464.03d |
| 277 | 1.2.1.2.5.1 | Modify Cancellation Standard Operating Procedures | 1d | 2007-01-01 | 2007-01-01 | 746.83d |
| 278 | 1.2.1.2.5.2 | Create Collection Standard Operating Procedures | 1d | 2007-01-01 | 2007-01-01 | 746.83d |
| 279 | 1.2.1.2.5.3 | Create Commercial Lines Client Setup Standard Operating Procedures | 1d | 2007-01-01 | 2007-01-01 | 746.83d |
| 280 | 1.2.1.2.5.4 | Procedures to Handle Cash at Branches | 1d | 2007-01-01 | 2007-01-01 | 746.83d |
| 281 | 1.2.1.2.5.5 | **Develop Standard Operating Procedures** | 1d | 2007-01-01 | 2007-01-01 | 487.03d |
| 282 | 1.2.1.2.5.5.1 | Prepare Table of Contents | 1d | 2007-01-01 | 2007-01-01 | 746.83d |
| 283 | 1.2.1.2.5.5.2 | Prepare Document Introduction & Overview | 1d | 2007-01-01 | 2007-01-01 | 746.83d |
| 284 | 1.2.1.2.5.5.3 | Prepare User Procedures | 1d | 2007-01-01 | 2007-01-01 | 746.83d |
| 285 | 1.2.1.2.5.5.4 | Assemble Input Forms | 1d | 2007-01-01 | 2007-01-01 | 746.83d |
| 286 | 1.2.1.2.5.5.5 | Translations? | 1d | 2007-01-01 | 2007-01-01 | 746.83d |
| 287 | 1.2.1.2.5.5.6 | Obtain Approval on User Procedures | 1d | 2007-01-01 | 2007-01-01 | 746.83d |

| ID | WBS | Task | Type | Duration | Start | Finish | Total slack | Text10 |
| --- | --- | --- | --- | --- | --- | --- | --- | --- |
| 288 | 1.2.1.2.5.6 | **Training** |  | 24d | 2007-01-01 | 2007-02-01 | 464.03d |  |
| 289 | 1.2.1.2.5.6.1 | **Develop detailed training strategy and plan (e.g. CBT, Train the Trainer)** |  | 1.35d | 2007-01-01 | 2007-01-02 | 486.68d |  |
| 290 | 1.2.1.2.5.6.1.1 | **Conduct Needs Assessment** |  | 1.35d | 2007-01-01 | 2007-01-02 | 486.68d |  |
| 291 | 1.2.1.2.5.6.1.1.1 | Determine User Population and Analysis |  | 1.35d | 2007-01-01 | 2007-01-02 | 746.48d |  |
| 292 | 1.2.1.2.5.6.1.1.2 | Identify User Training Philosophy and Approach |  | 1.35d | 2007-01-01 | 2007-01-02 | 746.48d |  |
| 293 | 1.2.1.2.5.6.1.1.3 | Determine High-Priority Areas |  | 1.35d | 2007-01-01 | 2007-01-02 | 746.48d |  |
| 294 | 1.2.1.2.5.6.1.1.4 | Determine Roles and Responsibilities |  | 1.35d | 2007-01-01 | 2007-01-02 | 746.48d |  |
| 295 | 1.2.1.2.5.6.1.1.5 | Revise Plan based on Needs Assessment |  | 1d | 2007-01-01 | 2007-01-01 | 746.83d |  |
| 296 | 1.2.1.2.5.6.2 | **Develop Training Course Materials** |  | 10.81d | 2007-01-01 | 2007-01-15 | 477.22d |  |
| 297 | 1.2.1.2.5.6.2.1 | Determine learning objectives for each course and course module |  | 2.7d | 2007-01-01 | 2007-01-03 | 745.13d |  |
| 298 | 1.2.1.2.5.6.2.2 | Prepare Student Materials (by process) |  | 10.81d | 2007-01-01 | 2007-01-15 | 737.02d |  |
| 299 | 1.2.1.2.5.6.2.3 | Prepare Application-Specific Training Exercises |  | 5.41d | 2007-01-01 | 2007-01-08 | 742.43d |  |
| 300 | 1.2.1.2.5.6.2.4 | Review Training Course Materials |  | 2.7d | 2007-01-01 | 2007-01-03 | 745.13d |  |
| 301 | 1.2.1.2.5.6.2.5 | Obtain Approval on Training Approach & Materials | milestone | 0d | 2007-01-01 | 2007-01-01 | 747.83d |  |
| 302 | 1.2.1.2.5.6.3 | Translations? |  | 24d | 2007-01-01 | 2007-02-01 | 723.83d |  |
| 303 | 1.2.1.2.5.6.4 | **Org Rollout - Training Environment** |  | 1d | 2007-01-01 | 2007-01-01 | 487.03d |  |
| 304 | 1.2.1.2.5.6.4.1 | Confirm and Set up mainframe region |  | 1d | 2007-01-01 | 2007-01-01 | 746.83d |  |
| 305 | 1.2.1.2.5.6.5 | **Deliver Training** |  | 1d | 2007-01-01 | 2007-01-01 | 487.03d |  |
| 306 | 1.2.1.2.5.6.5.1 | **Training Sessions** |  | 1d | 2007-01-01 | 2007-01-01 | 487.03d |  |
| 307 | 1.2.1.2.5.6.5.1.1 | Process Education Workshops |  | 1d | 2007-01-01 | 2007-01-01 | 746.83d |  |
| 308 | 1.2.1.2.5.6.5.1.2 | Technology |  | 1d | 2007-01-01 | 2007-01-01 | 746.83d |  |
| 309 | 1.2.1.2.5.6.5.1.3 | Competency |  | 1d | 2007-01-01 | 2007-01-01 | 746.83d |  |
| 310 | 1.2.1.2.5.6.5.2 | <dept> |  | 1d | 2007-01-01 | 2007-01-01 | 746.83d |  |
| 311 | 1.2.1.3 | **Development Track** |  | 10d | 2007-01-01 | 2007-01-12 | 478.03d |  |
| 312 | 2.3 | **J. Custom Code Interfaces, Extensions, and Bolt-ons Design/Build** |  | 10d | 2007-01-01 | 2007-01-12 | 478.03d | ORA02100000.htm |
| 313 | 1.2.1.3.1.1 | Confirm Requirements |  | 1.25d | 2007-01-01 | 2007-01-02 | 746.58d |  |

| ID | WBS | Task | Duration | Start | Finish | Total slack |
| --- | --- | --- | --- | --- | --- | --- |
| 314 | 1.2.1.3.1.2 | **Detailed Design** | 5d | 2007-01-01 | 2007-01-05 | 483.03d |
| 315 | 1.2.1.3.1.2.1 | Order Micr Encoded Statement paper | 1d | 2007-01-01 | 2007-01-01 | 746.83d |
| 316 | 1.2.1.3.1.2.2 | Confirm Cheque Stock | 1d | 2007-01-01 | 2007-01-01 | 746.83d |
| 317 | 1.2.1.3.1.2.3 | Review Use Cases | 2.5d | 2007-01-01 | 2007-01-03 | 745.33d |
| 318 | 1.2.1.3.1.2.4 | Company Bill For Commercial Property | 2d | 2007-01-01 | 2007-01-02 | 745.83d |
| 319 | 1.2.1.3.1.2.5 | Confirm Payment Options Available with CCIN Number | 1d | 2007-01-01 | 2007-01-01 | 746.83d |
| 320 | 1.2.1.3.1.2.6 | Expanded Payment Options - Modify Bill Statement | 3.75d | 2007-01-01 | 2007-01-04 | 744.08d |
| 321 | 1.2.1.3.1.2.7 | Acre Changes | 5d | 2007-01-01 | 2007-01-05 | 742.83d |
| 322 | 1.2.1.3.1.3 | **Build and Unit Test** | 10d | 2007-01-01 | 2007-01-12 | 478.03d |
| 323 | 1.2.1.3.1.3.1 | Develop Unit Test Plan and Cases from Use Cases) | 3.12d | 2007-01-01 | 2007-01-04 | 744.71d |
| 324 | 1.2.1.3.1.3.2 | Company Bill For Commercial Property | 5d | 2007-01-01 | 2007-01-05 | 742.83d |
| 325 | 1.2.1.3.1.3.3 | Expanded Payment Options - Modify Bill Statement | 6.25d | 2007-01-01 | 2007-01-09 | 741.58d |
| 326 | 1.2.1.3.1.3.4 | Acre Changes | 10d | 2007-01-01 | 2007-01-12 | 737.83d |
| 327 | 1.2.1.3.1.3.5 | Migrate into QUA | 1d | 2007-01-01 | 2007-01-01 | 746.83d |
| 328 | 1.2.1.4 | **Facilities Track** | 1d | 2007-01-01 | 2007-01-01 | 487.03d |
| 329 | 1.2.1.4.1 | **Determine Requirements** | 1d | 2007-01-01 | 2007-01-01 | 487.03d |
| 330 | 1.2.1.4.1.1 | PCs | 1d | 2007-01-01 | 2007-01-01 | 746.83d |
| 331 | 1.2.1.4.1.2 | Infrastructure (Desks, Chairs…) | 1d | 2007-01-01 | 2007-01-01 | 746.83d |
| 332 | 1.2.1.4.1.3 | Cabling | 1d | 2007-01-01 | 2007-01-01 | 746.83d |
| 333 | 1.2.1.4.1.4 | Phones | 1d | 2007-01-01 | 2007-01-01 | 746.83d |
| 334 | 1.2.1.4.1.5 | Other Equipment - Fax, Photocopier | 1d | 2007-01-01 | 2007-01-01 | 746.83d |
| 335 | 1.2.1.4.2 | ……….. | 1d | 2007-01-01 | 2007-01-01 | 746.83d |
| 336 | 1.2.2 | **Integrate Stage** | 15d | 2007-01-01 | 2007-01-19 | 473.03d |
| 337 | 1.2.2.1 | **System & Integration Testing** | 15d | 2007-01-01 | 2007-01-19 | 473.03d |
| 338 | 1.2.2.1.1 | **Develop Testing Strategy and Plan** | 15d | 2007-01-01 | 2007-01-19 | 473.03d |
| 339 | 1.2.2.1.1.1 | **Prepare Test Strategy document** | 1d | 2007-01-01 | 2007-01-01 | 487.03d |
| 340 | 1.2.2.1.1.1.1 | Define Scope of The System Test and Cycles | 1d | 2007-01-01 | 2007-01-01 | 487.03d |
| 341 | 1.2.2.1.1.1.2 | Determine System Test Team Members and Responsibilities | 1d | 2007-01-01 | 2007-01-01 | 487.03d |

| ID | WBS | Task | Duration | Start | Finish | Total slack |
| --- | --- | --- | --- | --- | --- | --- |
| 342 | 1.2.2.1.1.2 | **Complete the System Test Team Orientation** | 1d | 2007-01-01 | 2007-01-01 | 487.03d |
| 343 | 1.2.2.1.1.2.1 | Conduct structured walk-through of test plan, roles, responsibilities | 1d | 2007-01-01 | 2007-01-01 | 487.03d |
| 344 | 1.2.2.1.1.3 | Obtain Approval of System Test Strategy & Plan | 1d | 2007-01-01 | 2007-01-01 | 487.03d |
| 345 | 1.2.2.1.1.4 | Develop System Plans and Test Scripts | 1d | 2007-01-01 | 2007-01-01 | 487.03d |
| 346 | 1.2.2.1.1.5 | Obtain Approval on Test Scripts | 1d | 2007-01-01 | 2007-01-01 | 487.03d |
| 347 | 1.2.2.1.1.6 | **Execute System Test** | 15d | 2007-01-01 | 2007-01-19 | 473.03d |
| 348 | 1.2.2.1.1.6.1 | **Conduct System Testing** | 15d | 2007-01-01 | 2007-01-19 | 473.03d |
| 349 | 1.2.2.1.1.6.1.1 | Execute Test Cycles | 15d | 2007-01-01 | 2007-01-19 | 473.03d |
| 350 | 1.2.2.1.1.6.1.2 | Evaluate System Test Results | 15d | 2007-01-01 | 2007-01-19 | 473.03d |
| 351 | 1.2.2.1.1.6.2 | **Provide System Test Support** | 1d | 2007-01-01 | 2007-01-01 | 487.03d |
| 352 | 1.2.2.1.1.6.2.1 | Functional Support | 1d | 2007-01-01 | 2007-01-01 | 487.03d |
| 353 | 1.2.2.1.1.6.2.2 | Technical Support / Corrections | 1d | 2007-01-01 | 2007-01-01 | 487.03d |
| 354 | 1.2.2.1.1.6.2.3 | Document and Log All Errors | 1d | 2007-01-01 | 2007-01-01 | 487.03d |
| 355 | 1.2.2.1.1.6.2.4 | Document and Resolve Specification or Design Changes | 1d | 2007-01-01 | 2007-01-01 | 487.03d |
| 356 | 1.2.2.1.1.6.2.5 | File System Test Results for Completed Test Cycles | 1d | 2007-01-01 | 2007-01-01 | 487.03d |
| 357 | 1.2.2.1.1.6.2.6 | Submit System Test Results to Management & Obtain Approval | 1d | 2007-01-01 | 2007-01-01 | 487.03d |
| 358 | 1.2.3 | **Implement Stage** | 1d | 2007-01-01 | 2007-01-01 | 487.03d |
| 359 | 1.2.3.1 | **Execute Cutover and Rollout** | 1d | 2007-01-01 | 2007-01-01 | 487.03d |
| 360 | 1.2.3.1.1 | **System Test to Production Migration** | 1d | 2007-01-01 | 2007-01-01 | 487.03d |
| 361 | 1.2.3.1.1.1 | Prepare Detailed Implementation Package | 0.28d | 2007-01-01 | 2007-01-01 | 747.56d |
| 362 | 1.2.3.1.1.2 | Migrate to Production | 1d | 2007-01-01 | 2007-01-01 | 746.83d |
| 363 | 1.2.3.1.2 | **Production Readiness** | 1d | 2007-01-01 | 2007-01-01 | 487.03d |
| 364 | 1.2.3.1.2.1 | Inform Help Desk of Changes | 0.62d | 2007-01-01 | 2007-01-01 | 747.21d |
| 365 | 1.2.3.1.2.2 | Inform Computer Operations of Changes | 0.62d | 2007-01-01 | 2007-01-01 | 747.21d |
| 366 | 1.2.3.1.2.3 | Setup Security | 1d | 2007-01-01 | 2007-01-01 | 746.83d |

| ID | WBS | Task | Duration | Start | Finish | Total slack |
| --- | --- | --- | --- | --- | --- | --- |
| 367 | 1.2.3.1.2.4 | **Facilities** | 1d | 2007-01-01 | 2007-01-01 | 487.03d |
| 368 | 1.2.3.1.2.4.1 | Verify Equipment, Materials, Workstations | 1d | 2007-01-01 | 2007-01-01 | 746.83d |
| 369 | 1.2.3.1.3 | **Validate Cutover Readiness** | 1d | 2007-01-01 | 2007-01-01 | 487.03d |
| 370 | 1.2.3.1.3.1 | Verify execution of organizational and facilities changes | 0.5d | 2007-01-01 | 2007-01-01 | 747.33d |
| 371 | 1.2.3.1.3.2 | Ensure end users training plan has been executed | 1d | 2007-01-01 | 2007-01-01 | 746.83d |
| 372 | 1.2.3.1.3.3 | Ensure go live support model is in place | 0.5d | 2007-01-01 | 2007-01-01 | 747.33d |
| 373 | 1.2.3.1.3.4 | Verify execution of all security and controls procedures | 0.25d | 2007-01-01 | 2007-01-01 | 747.58d |
| 374 | 1.2.3.1.3.5 | Ensure controlled user startup plan is ready | 0.5d | 2007-01-01 | 2007-01-01 | 747.33d |
| 375 | 1.2.3.1.3.6 | Ensure all areas involved in detailed cutover timeline are ready | 1d | 2007-01-01 | 2007-01-01 | 746.83d |
| 376 | 1.2.3.1.3.7 | Ensure contingency plan is complete/validated | 1d | 2007-01-01 | 2007-01-01 | 746.83d |
| 377 | 1.2.3.1.3.8 | Review Open Issues | 1d | 2007-01-01 | 2007-01-01 | 746.83d |
| 378 | 1.2.3.1.3.9 | Make final go/no go decision | 1d | 2007-01-01 | 2007-01-01 | 746.83d |
| 379 | 1.2.3.1.3.10 | Schedule and conduct final cutover briefing | 0.5d | 2007-01-01 | 2007-01-01 | 747.33d |
| 380 | 1.2.3.1.3.11 | End User Information Sessions | 0.5d | 2007-01-01 | 2007-01-01 | 747.33d |
| 381 | 1.2.3.1.3.12 | Obtain final approval for Cutover | 0.5d | 2007-01-01 | 2007-01-01 | 747.33d |
| 382 | 1.2.3.1.3.13 | Ongoing Cutover Activities Monitoring | 1d | 2007-01-01 | 2007-01-01 | 746.83d |
| 383 | 1.2.3.1.4 | Execute Cutover Timeline | 1d | 2007-01-01 | 2007-01-01 | 746.83d |
| 384 | 1.2.3.2 | **Post Implementation Support** | 1d | 2007-01-01 | 2007-01-01 | 487.03d |
| 385 | 1.2.3.2.1 | Go Live | 1d | 2007-01-01 | 2007-01-01 | 746.83d |
| 386 | 1.2.3.2.2 | Create measures/checks to validate user entry for reasonableness and accuracy | 1d | 2007-01-01 | 2007-01-01 | 746.83d |
| 387 | 1.2.3.2.3 | Provide Post Implementation Support | 1d | 2007-01-01 | 2007-01-01 | 746.83d |
| 388 | 1.3 | **Decision Points - Combine with Rollout (Iterative)** | 1d | 2007-01-01 | 2007-01-01 | 487.03d |
| 389 | 1.3.1 | **Business Processes and Rules** | 1d | 2007-01-01 | 2007-01-01 | 487.03d |
| 390 | 1.3.1.1 | Assess Results | 1d | 2007-01-01 | 2007-01-01 | 487.03d |
| 391 | 1.3.1.2 | Review Issues and Recommend Changes | 1d | 2007-01-01 | 2007-01-01 | 487.03d |

| ID | WBS | Task | Duration | Start | Finish | Predecessors | Remaining | Total slack | Free slack | Constraint | Resources | Work | Text1 |
| --- | --- | --- | --- | --- | --- | --- | --- | --- | --- | --- | --- | --- | --- |
| 392 | 1.4 | **Rollout** | 488.03d | 2007-01-01 A | 2008-11-13 |  | 486.91d | 0d |  |  |  | 6269.87h |  |
| 393 | 1.4.1 | **Design/Build Stage** | 488.03d | 2007-01-01 A | 2008-11-13 |  | 486.06d | 0d |  |  |  | 4301.73h |  |
| 394 | 1.4.1.1 | **Process/Business Track** | 182.38d | 2007-01-01 | 2007-09-12 |  |  | 0d |  |  |  | 382.13h |  |
| 395 | 1.4.1.1.1 | **Process Analysis** | 19.55d | 2007-01-01 | 2007-01-26 |  |  | 347.46d |  |  |  | 291.73h |  |
| 396 | 1.4.1.1.1.1 | **Define Target Solution** | 19.55d | 2007-01-01 | 2007-01-26 |  |  | 347.46d |  |  |  | 291.73h |  |
| 397 | 1.4.1.1.1.1.1 | **Processes** | 14.62d | 2007-01-01 | 2007-01-19 |  |  | 347.46d |  |  |  | 148.34h |  |
| 398 | 1.4.1.1.1.1.1.1 | Review Best Practices | 2d | 2007-01-01 | 2007-01-02 |  |  | 483.23d | 0d | start no earlier than 2007-01-01 |  |  | Rob, Sonia |
| 399 | 1.4.1.1.1.1.1.2 | Identify Critical Processes - Review Draft Detailed SOPs/Processes | 2.8d | 2007-01-03 | 2007-01-05 | 398 |  | 483.23d |  |  |  |  | Rob, Lois |
| 400 | 1.4.1.1.1.1.1.3 | Process GAP from Current Environment | 2.7d | 2007-01-01 | 2007-01-03 |  |  | 347.46d | 0d |  | Process Analyst | 21.6h | Sonia |
| 401 | 1.4.1.1.1.1.1.4 | Validation Workshops - Broader Stakeholders | 7.92d | 2007-01-03 | 2007-01-15 | 400 |  | 347.46d | 0d |  | Process Analyst; Business SME | 126.74h | Sonia, Rob |
| 402 | 1.4.1.1.1.1.1.5 | Imput from Brokers | 2d | 2007-01-15 | 2007-01-17 | 401 |  | 347.46d | 0d |  |  |  | Rob |
| 403 | 1.4.1.1.1.1.1.6 | Process Peer Review | 1d | 2007-01-17 | 2007-01-18 | 402 |  | 347.46d | 0d |  |  |  | Sonia |
| 404 | 1.4.1.1.1.1.1.7 | Obtain Approval on Preliminary Processes | 1d | 2007-01-18 | 2007-01-19 | 403 |  | 347.46d | 0d |  |  |  |  |
| 405 | 1.4.1.1.1.1.2 | Review with Internal Audit | 2d | 2007-01-19 | 2007-01-23 | 404 |  | 471.41d |  |  |  |  | Sonia, Rob |
| 406 | 1.5.1.1.1.1.2 | **Develop business rules** | 19.55d | 2007-01-01 | 2007-01-26 |  |  | 406.08d |  |  |  | 143.39h |  |
| 407 | 1.5.1.1.1.1.2.1 | Document draft business rules | 10d | 2007-01-01 | 2007-01-12 |  |  | 478.03d |  | start no earlier than 2007-01-01 | Business SME | 80h | Lois, Rob |
| 408 | 1.5.1.1.1.1.2.2 | Finalize business rules | 7.92d | 2007-01-15 | 2007-01-25 | 401 |  | 395.46d | 0d |  | Business SME | 63.39h | Rob |
| 409 | 1.5.1.1.1.1.2.3 | Obtain Approval on Business Rules | 1d | 2007-01-25 | 2007-01-26 | 408 |  | 395.46d | 0d |  |  |  |  |
| 410 | 1.5.1.1.1.1.4 | Refine Project Plan/Obtain Approval | 2d | 2007-01-01 | 2007-01-02 |  |  | 486.03d |  |  |  |  |  |
| 411 | 1.4.1.1.2 | **Revise Based on Feedback From Centralization** | 8d | 2007-01-01 | 2007-01-10 |  |  | 480.03d |  |  |  |  |  |
| 412 | 1.4.1.1.2.1 | Revise Business Processes, Rules and Use Cases | 7d | 2007-01-01 | 2007-01-09 |  |  | 480.03d | 0d | start no earlier than 2007-01-01 |  |  | Lois, Sonia |
| 413 | 1.4.1.1.2.2 | Obtain Approval on Revisions | 1d | 2007-01-10 | 2007-01-10 | 412 |  | 480.03d |  |  |  |  |  |
| 414 | 1.4.1.1.3 | **Solution Design, Build and Test** | 92.58d | 2007-01-01 | 2007-05-09 |  |  | 0d |  |  |  | 82.4h |  |
| 415 | 1.4.1.1.3.1 | **Forms Design** | 73.03d | 2007-01-26 | 2007-05-09 |  |  | 395.46d |  |  |  |  |  |
| 416 | 1.4.1.1.3.1.1 | Authorization Form | 17d | 2007-01-26 | 2007-02-20 | 409 |  | 395.46d | 0d |  |  |  | Bonnie, Rob |
| 417 | 1.4.1.1.3.1.2 | Dunning Letter | 5.03d | 2007-02-20 | 2007-02-27 | 416 |  | 395.46d | 0d |  |  |  | Bonnie, Rob |
| 418 | 1.4.1.1.3.1.3 | Registered Letter Form | 17d | 2007-02-27 | 2007-03-22 | 417 |  | 395.46d | 0d |  |  |  | Bonnie, Rob |
| 419 | 1.4.1.1.3.1.4 | Misc. | 34d | 2007-03-22 | 2007-05-09 | 418 |  | 395.46d |  |  |  |  | Bonnie, Rob |

| ID | WBS | Task | Duration | Start | Finish | Predecessors | Total slack | Free slack | Resources | Work | Text1 |
| --- | --- | --- | --- | --- | --- | --- | --- | --- | --- | --- | --- |
| 420 | 1.4.1.1.3.2 | **Revise and Finalize Based on Feedback** | 15.3d | 2007-01-01 | 2007-01-22 |  | 0d |  |  | 82.4h |  |
| 421 | 1.4.1.1.3.2.1 | Setups | 2d | 2007-01-01 | 2007-01-02 |  | 0d |  |  |  | Lois |
| 422 | 1.4.1.1.3.2.2 | Requirements - Use Cases | 7.7d | 2007-01-03 | 2007-01-12 | 421 | 0d |  |  |  | Lois |
| 423 | 1.4.1.1.3.2.3 | Processes | 3.6d | 2007-01-03 | 2007-01-08 | 421 | 9.7d |  | Process Analyst | 28.8h | Sonia, Rob |
| 424 | 1.4.1.1.3.2.4 | Business Rules | 6.7d | 2007-01-03 | 2007-01-11 | 421 | 6.6d |  | Business SME | 53.6h | Lois, Rob, ? |
| 425 | 1.4.1.1.3.2.5 | Confirm Technology Integration Design | 5.6d | 2007-01-12 | 2007-01-22 | 422 | 0d |  |  |  | Ba, Les |
| 426 | 1.4.1.1.3.2.6 | Revise and Revise Client Service Standards | 2.5d | 2007-01-01 | 2007-01-03 |  | 12.8d | 0d |  |  | Rob, Bonnie |
| 427 | 1.4.1.1.3.3 | **Freeze Design** | 1d | 2007-01-03 | 2007-01-04 |  | 393.76d | 0d |  |  |  |
| 428 | 1.4.1.1.3.3.1 | Obtain Approval Processes, Setups, Rules, Requirements, SLAs | 1d | 2007-01-03 | 2007-01-04 | 426 | 393.76d |  |  |  |  |
| 429 | 1.4.1.1.3.4 | **All Integration** | 86.55d | 2007-01-01 | 2007-05-01 |  | 0d |  |  |  |  |
| 430 | 1.4.1.1.3.4.1 | Test Plan | 1d | 2007-01-22 | 2007-01-23 | 420 | 0d |  |  |  | Rick, Ba |
| 431 | 1.4.1.1.3.4.2 | **Prepare for Test** | 70.25d | 2007-01-23 | 2007-05-01 |  | 0d |  |  |  |  |
| 432 | 1.4.1.1.3.4.2.1 | Prepare Scenarios | 61.25d | 2007-01-23 | 2007-04-18 | 430 | 0d |  |  |  | Lois, Ba |
| 433 | 1.4.1.1.3.4.2.2 | Setup Testing Instance | 9d | 2007-04-18 | 2007-05-01 | 432 | 0d |  |  |  | Lois, Ba |
| 434 | 1.4.1.1.3.4.3 | Execute Testing | 1d | 2007-01-01 | 2007-01-01 |  | 85.55d |  |  |  |  |
| 435 | 1.4.1.1.3.4.4 | Review Results | 1d | 2007-01-01 | 2007-01-01 |  | 75.85d | 0d |  |  | Rick |
| 436 | 1.4.1.1.3.4.5 | Document Issues & Action Plan | 2d | 2007-01-02 | 2007-01-03 | 435 | 75.85d | 0d |  |  | Rick |
| 437 | 1.4.1.1.3.4.6 | Follow-ups on Action Plan | 7.7d | 2007-01-04 | 2007-01-15 | 436 | 75.85d |  |  |  | Entire Team |
| 438 | 1.4.1.1.4 | **Security and Controls** | 11d | 2007-01-01 | 2007-01-15 |  | 477.03d |  |  | 8h |  |
| 439 | 1.4.1.1.4.1 | Confirm Deliverable Templates | 0.5d | 2007-01-01 | 2007-01-01 |  | 477.03d | 0d |  |  | Rick |
| 440 | 1.4.1.1.4.2 | **Develop Access Control Matrix** | 10.5d | 2007-01-01 | 2007-01-15 |  | 477.03d |  |  |  |  |
| 441 | 1.4.1.1.4.2.1 | Decompose security level requirements into security responsibility | 1d | 2007-01-01 | 2007-01-02 | 439 | 477.03d | 0d |  |  | Lois |
| 442 | 1.4.1.1.4.2.2 | Identify Reporting Security (request groups) | 1d | 2007-01-02 | 2007-01-03 | 441 | 477.03d | 0d |  |  | Lois |
| 443 | 1.4.1.1.4.2.3 | Review Access Control Matrix to identify segregation of duties | 1d | 2007-01-03 | 2007-01-04 | 442 | 477.03d | 0d |  |  | Lois |
| 444 | 1.4.1.1.4.2.4 | Identify Unique User-IDs for each Responsibility | 1d | 2007-01-04 | 2007-01-05 | 443 | 477.03d | 0d |  |  | Lois |
| 445 | 1.4.1.1.4.2.5 | Design Basic User Menus for each Responsibility | 1d | 2007-01-05 | 2007-01-08 | 444 | 477.03d | 0d |  |  | Yvonne |
| 446 | 1.4.1.1.4.2.6 | User Profiles | 1.5d | 2007-01-08 | 2007-01-09 | 445 | 477.03d | 0d |  |  | Lois, Ba |
| 447 | 1.4.1.1.4.2.7 | Build each Security Responsibility in Oracle (dev. environment) | 1d | 2007-01-10 | 2007-01-10 | 446 | 477.03d | 0d |  |  | Yvonne |
| 448 | 1.4.1.1.4.2.8 | Build Request Groups | 1d | 2007-01-11 | 2007-01-11 | 447 | 477.03d | 0d |  |  | Yvonne |
| 449 | 1.4.1.1.4.2.9 | Prototype (CRP2) and confirm each responsibility - Part of CRP2 | 1d | 2007-01-12 | 2007-01-12 | 448 | 477.03d | 0d |  |  | Lois |
| 450 | 1.4.1.1.4.2.10 | Review responsibility design with internal audit | 1d | 2007-01-15 | 2007-01-15 | 449 | 477.03d |  |  |  | Lois |

| ID | WBS | Task | Duration | Start | Finish | Predecessors | Total slack | Free slack | Constraint | Resources | Work | Text1 |
| --- | --- | --- | --- | --- | --- | --- | --- | --- | --- | --- | --- | --- |
| 451 | 1.4.1.1.4.3 | **Review System Administration and Contingency Planning** | 6d | 2007-01-01 | 2007-01-09 |  | 481.53d |  |  |  | 8h |  |
| 452 | 1.4.1.1.4.3.1 | Evaluate provisions for Oracle System Administration | 1d | 2007-01-01 | 2007-01-02 | 439 | 481.53d | 0d |  |  |  | Joe |
| 453 | 1.4.1.1.4.3.2 | Evaluate physical security controls | 1d | 2007-01-02 | 2007-01-03 | 452 | 481.53d | 0d |  |  |  | Joe |
| 454 | 1.4.1.1.4.3.3 | Evaluate provisions for DBMS security administration | 1d | 2007-01-03 | 2007-01-04 | 453 | 481.53d | 0d |  |  |  | Joe |
| 455 | 1.4.1.1.4.3.4 | Evaluate provisions for network security administration | 1d | 2007-01-04 | 2007-01-05 | 454 | 481.53d | 0d |  | Network Analyst | 8h | Network Analyst |
| 456 | 1.4.1.1.4.3.5 | Incorporate Failover Strategies - Evaluate provisions for system/business continuity planning for Oracle | 2d | 2007-01-05 | 2007-01-09 | 455 | 481.53d |  |  |  |  | Joe |
| 457 | 1.4.1.1.5 | **Cutover Planning** | 122.35d | 2007-03-26 | 2007-09-12 |  | 305.65d |  |  |  |  |  |
| 458 | 1.4.1.1.5.1 | Confirm Deliverable Templates | 50d | 2007-03-26 | 2007-06-04 | 795SS-49d | 305.65d | 0d | start no earlier than 2007-01-01 |  |  | Rick |
| 459 | 1.4.1.1.5.2 | **Prepare Cutover Task Plans** | 24.1d | 2007-06-04 | 2007-07-06 |  | 305.65d | 0d |  |  |  |  |
| 460 | 1.4.1.1.5.2.1 | Develop High Level Cutover Approach/Strategy | 14.5d | 2007-06-04 | 2007-06-22 | 458 | 305.65d | 0d | start no earlier than 2007-01-01 |  |  | Rick |
| 461 | 1.4.1.1.5.2.2 | Develop details for support models (resources, roles, etc.) | 1.8d | 2007-06-22 | 2007-06-26 | 460 | 305.65d | 0d |  |  |  | Kathy |
| 462 | 1.4.1.1.5.2.3 | Develop Final Data Conversion Plan Including Manual Transactions | 1d | 2007-06-26 | 2007-06-27 | 461 | 305.65d | 0d |  |  |  | Ba |
| 463 | 1.4.1.1.5.2.4 | Prepare controlled user startup plan (waves) | 1.8d | 2007-06-27 | 2007-06-29 | 462 | 305.65d | 0d |  |  |  | Rob |
| 464 | 1.4.1.1.5.2.5 | Develop detailed cutover timeline | 2d | 2007-06-29 | 2007-07-03 | 463 | 305.65d | 0d |  |  |  | Rick |
| 465 | 1.4.1.1.5.2.6 | Compile/refine contingency plan | 1d | 2007-07-03 | 2007-07-04 | 464 | 305.65d | 0d |  |  |  | Rick |
| 466 | 1.4.1.1.5.2.7 | Obtain Approval of Strategy and Plan | 1d | 2007-07-04 | 2007-07-05 | 465 | 305.65d | 0d |  |  |  |  |
| 467 | 1.4.1.1.5.2.8 | Integrate cutover timeline with project plan | 1d | 2007-07-05 | 2007-07-06 | 466 | 305.65d |  |  |  |  | Rick |
| 468 | 1.4.1.1.5.3 | **Prepare for Final Production Environment** | 13.25d | 2007-07-27 | 2007-08-15 |  | 305.65d |  |  |  |  |  |
| 469 | 1.4.1.1.5.3.1 | Confirm readiness of hardware | 1d | 2007-07-27 | 2007-07-30 | 459FS+15d | 305.65d | 0d |  |  |  | Joe |
| 470 | 1.4.1.1.5.3.2 | Confirm readiness of software | 2d | 2007-07-30 | 2007-08-01 | 469 | 305.65d | 0d |  |  |  | Joe |
| 471 | 1.4.1.1.5.3.3 | Confirm readiness of network | 1d | 2007-08-01 | 2007-08-02 | 470 | 305.65d | 0d |  |  |  | Joe |
| 472 | 1.4.1.1.5.3.4 | Confirm Service Level Agreements are in place | 1d | 2007-08-02 | 2007-08-03 | 471 | 305.65d | 0d |  |  |  | Rob |
| 473 | 1.4.1.1.5.3.5 | Confirm availability of peripheral equipment | 1d | 2007-08-03 | 2007-08-06 | 472 | 305.65d | 0d |  |  |  | Joe |
| 474 | 1.4.1.1.5.3.6 | Confirm availability of all other equipment | 1d | 2007-08-06 | 2007-08-07 | 473 | 305.65d | 0d |  |  |  | Joe |
| 475 | 1.4.1.1.5.3.7 | Confirm operational processes are in place for production environment | 1d | 2007-08-07 | 2007-08-08 | 474 | 305.65d | 0d |  |  |  | Joe |
| 476 | 1.4.1.1.5.3.8 | Confirm functional processes are signed off | 3.25d | 2007-08-08 | 2007-08-13 | 475 | 305.65d | 0d |  |  |  | Rob |
| 477 | 1.4.1.1.5.3.9 | Define Team Transition Activities | 1d | 2007-08-13 | 2007-08-14 | 476 | 305.65d | 0d |  |  |  | Kathy |
| 478 | 1.4.1.1.5.3.10 | Define Project Management Transition Activities | 1d | 2007-08-14 | 2007-08-15 | 477 | 305.65d | 0d |  |  |  | Rick |
| 479 | 1.4.1.1.5.4 | Prepare Detailed Installation Checklist | 20d | 2007-08-15 | 2007-09-12 | 478 | 305.65d |  |  |  |  | Rick |

| ID | WBS | Task | Duration | Start | Finish | Predecessors | Total slack | Free slack | Constraint | Work | Text1 |
| --- | --- | --- | --- | --- | --- | --- | --- | --- | --- | --- | --- |
| 480 | 1.4.1.2 | **Change Management Track** | 148d | 2007-01-01 | 2007-07-25 |  | 340.03d |  |  | 1625.2h |  |
| 481 | 1.4.1.2.1 | **Develop Change Strategy** | 42.3d | 2007-01-01 | 2007-02-28 |  | 445.73d |  |  |  |  |
| 482 | 1.4.1.2.1.1 | **Project Team Effectiveness and Mobilization** | 42.3d | 2007-01-01 | 2007-02-28 |  | 445.73d |  |  |  |  |
| 483 | 1.4.1.2.1.1.1 | **Mobilize project team** | 36.7d | 2007-01-01 | 2007-02-20 |  | 445.73d |  |  |  |  |
| 484 | 1.4.1.2.1.1.1.1 | Confirm Project Team structure, roles and responsibilities | 1d | 2007-01-01 | 2007-01-01 |  | 445.73d | 0d | start no earlier than 2007-01-01 |  | Rick |
| 485 | 1.4.1.2.1.1.1.2 | Obtain approval from Steering Community on Role, Responsibility, level of effort and Membership | 1d | 2007-01-02 | 2007-01-02 | 484 | 445.73d | 0d |  |  | Rick |
| 486 | 1.4.1.2.1.1.1.3 | One on One Meetings - Roles and Resp | 10d | 2007-01-03 | 2007-01-16 | 485 | 445.73d | 0d |  |  | Rick |
| 487 | 1.4.1.2.1.1.1.4 | Confirm Case for Change - Benefits | 6.2d | 2007-01-17 | 2007-01-25 | 486 | 445.73d | 0d |  |  | Rob |
| 488 | 1.4.1.2.1.1.1.5 | Project Charter - Scope, Approach, Schedules, Resources | 18.5d | 2007-01-25 | 2007-02-20 | 487 | 445.73d | 0d |  |  | Rick |
| 489 | 1.4.1.2.1.1.1.6 | Kick-off Meeting | 1d | 2007-01-01 | 2007-01-01 |  | 487.03d |  | start no earlier than 2007-01-01 |  | Rick, Kathy |
| 490 | 1.4.1.2.1.1.2 | Team Retention Strategy | 2.6d | 2007-02-20 | 2007-02-23 | 488 | 445.73d | 0d | start no earlier than 2007-01-01 |  | Kathy |
| 491 | 1.4.1.2.1.1.3 | Examine overall process for project team performance metrics | 1d | 2007-02-23 | 2007-02-26 | 490 | 445.73d | 0d |  |  | Lori |
| 492 | 1.4.1.2.1.1.4 | Define individual team member's performance objectives | 1d | 2007-02-26 | 2007-02-27 | 491 | 445.73d | 0d |  |  | Lori |
| 493 | 1.4.1.2.1.1.5 | Develop performance metrics for team | 1d | 2007-02-27 | 2007-02-28 | 492 | 445.73d |  |  |  | Lori |
| 494 | 1.4.1.2.1.2 | Assess Change Readiness | 1d | 2007-01-01 | 2007-01-01 |  | 487.03d |  |  |  |  |
| 495 | 1.4.1.2.1.3 | **Develop Stakeholder Engagement Strategies** | 4.12d | 2007-01-01 | 2007-01-05 |  | 479.16d |  |  |  |  |
| 496 | 1.4.1.2.1.3.1 | **Complete Strategies** | 3.12d | 2007-01-01 | 2007-01-04 |  | 479.16d |  |  |  |  |
| 497 | 1.4.1.2.1.3.1.1 | Align with Communication Plan | 0.62d | 2007-01-01 | 2007-01-01 |  | 479.16d | 0d |  |  | Kathy |
| 498 | 1.4.1.2.1.3.1.2 | Identify Specific Tactics | 0.62d | 2007-01-01 | 2007-01-02 | 497 | 479.16d | 0d |  |  | Kathy |
| 499 | 1.4.1.2.1.3.1.3 | Validate with Steering Committee | 0.62d | 2007-01-02 | 2007-01-02 | 498 | 479.16d | 0d |  |  | Kathy |
| 500 | 1.4.1.2.1.3.1.4 | Validate with Branch Mgr | 0.62d | 2007-01-02 | 2007-01-03 | 499 | 479.16d | 0d |  |  | Kathy |
| 501 | 1.4.1.2.1.3.1.5 | Present to Project Team, Finance, Affected Staff | 0.62d | 2007-01-03 | 2007-01-04 | 500 | 479.16d | 0d |  |  | Kathy |
| 502 | 1.4.1.2.1.3.2 | Obtain Approval | 1d | 2007-01-04 | 2007-01-05 | 501 | 479.16d | 0d |  |  |  |
| 503 | 1.4.1.2.1.4 | **Complete preliminary org. impact assessment** | 4.75d | 2007-01-05 | 2007-01-11 |  | 479.16d |  |  |  |  |
| 504 | 1.4.1.2.1.4.1 | Document Preliminary Org. Impacts | 1.88d | 2007-01-05 | 2007-01-08 | 502 | 479.16d | 0d |  |  | Kathy |
| 505 | 1.4.1.2.1.4.2 | Develop High-Level Strategies to Address Impacts | 1.88d | 2007-01-09 | 2007-01-10 | 504 | 479.16d | 0d |  |  | Kathy |
| 506 | 1.4.1.2.1.4.3 | Obtain Approval | 1d | 2007-01-10 | 2007-01-11 | 505 | 479.16d |  |  |  |  |

| ID | WBS | Task | Duration | Start | Finish | Predecessors | Total slack | Free slack | Constraint | Work | Text1 |
| --- | --- | --- | --- | --- | --- | --- | --- | --- | --- | --- | --- |
| 507 | 1.4.1.2.1.5 | **Communication Strategy/Plan** | 14.11d | 2007-01-01 | 2007-01-19 |  | 463.93d |  |  |  |  |
| 508 | 1.4.1.2.1.5.1 | Review existing communication program for all projects | 2.5d | 2007-01-01 | 2007-01-03 |  | 463.93d | 0d | start no earlier than 2007-01-01 |  | Lori |
| 509 | 1.4.1.2.1.5.2 | Confirm Change Messages and Target Audience | 1d | 2007-01-03 | 2007-01-04 | 508 | 463.93d | 0d |  |  | Lori |
| 510 | 1.4.1.2.1.5.3 | Establish Communication Vehicles | 1d | 2007-01-04 | 2007-01-05 | 509 | 463.93d | 0d |  |  | Lori |
| 511 | 1.4.1.2.1.5.4 | Revise Existing Communication Templates | 2d | 2007-01-05 | 2007-01-09 | 510 | 463.93d | 0d |  |  | Lori |
| 512 | 1.4.1.2.1.5.5 | Develop detailed Communication Plan and time-phased activities | 2.11d | 2007-01-09 | 2007-01-11 | 511 | 463.93d | 0d |  |  | Lori |
| 513 | 1.4.1.2.1.5.6 | Establish Feedback/ Monitoring Mechanisms | 2d | 2007-01-11 | 2007-01-15 | 512 | 463.93d | 0d |  |  | Lori |
| 514 | 1.4.1.2.1.5.7 | Adjust Strategy/Plan | 2.5d | 2007-01-15 | 2007-01-18 | 513 | 463.93d | 0d |  |  | Lori |
| 515 | 1.4.1.2.1.5.8 | Obtain Approval | 1d | 2007-01-18 | 2007-01-19 | 514 | 463.93d | 0d |  |  |  |
| 516 | 1.4.1.2.1.6 | **High-Level Training Strategy** | 6.25d | 2007-01-19 | 2007-01-29 |  | 467.68d |  |  |  |  |
| 517 | 1.4.1.2.1.6.1 | Assess Existing Training Structure | 1d | 2007-01-19 | 2007-01-22 | 515 | 467.68d | 0d |  |  | Lori |
| 518 | 1.4.1.2.1.6.2 | Determine capacity for effective delivery | 1d | 2007-01-22 | 2007-01-23 | 517 | 467.68d | 0d |  |  | Lori |
| 519 | 1.4.1.2.1.6.3 | Identify Lessons Learned | 1d | 2007-01-23 | 2007-01-24 | 518 | 467.68d | 0d |  |  | Lori |
| 520 | 1.4.1.2.1.6.4 | Develop Principles | 1d | 2007-01-24 | 2007-01-25 | 519 | 467.68d | 0d |  |  | Lori |
| 521 | 1.4.1.2.1.6.5 | Identify User Communities | 1d | 2007-01-25 | 2007-01-26 | 520 | 467.68d | 0d |  |  | Lori |
| 522 | 1.4.1.2.1.6.6 | Validate with Team | 1.25d | 2007-01-26 | 2007-01-29 | 521 | 467.68d |  | start no earlier than 2001-10-01 |  | Lori |
| 523 | 1.4.1.2.2 | **Project Team Training** | 2d | 2007-01-01 | 2007-01-02 |  | 486.03d |  |  |  |  |
| 524 | 1.4.1.2.2.1 | Develop Project Team Training Plan | 2d | 2007-01-01 | 2007-01-02 |  | 486.03d |  |  |  |  |
| 525 | 1.4.1.2.2.2 | Complete Core Project Team Training | 1d | 2007-01-01 | 2007-01-01 |  | 487.03d |  |  |  |  |
| 526 | 1.4.1.2.3 | **Manage the Change** | 148d | 2007-01-01 | 2007-07-25 |  | 340.03d |  |  | 1054.8h |  |
| 527 | 1.4.1.2.3.1 | **Knowledge Management** | 6d | 2007-01-19 | 2007-01-29 |  | 467.93d |  |  |  |  |
| 528 | 1.4.1.2.3.1.1 | Explore Knowledge Management Framework | 6d | 2007-01-19 | 2007-01-29 | 515 | 467.93d |  |  |  | Kathy |
| 529 | 1.4.1.2.3.2 | **Implement Stakeholder Engagement Strategies** | 10d | 2007-01-19 | 2007-02-02 |  | 463.93d |  |  |  |  |
| 530 | 1.4.1.2.3.2.1 | Ongoing - Develop & maintain network of Change Agents | 5d | 2007-01-19 | 2007-01-26 | 515 | 468.93d |  |  |  | Kathy |
| 531 | 1.4.1.2.3.2.2 | Ongoing - Monitor and Revise stakeholder mgmt strategy as required | 10d | 2007-01-19 | 2007-02-02 | 515 | 463.93d |  |  |  | Kathy |
| 532 | 1.4.1.2.3.2.3 | Ongoing - Change Mgmt Workshops | 5d | 2007-01-19 | 2007-01-26 | 515 | 468.93d |  |  |  | Kathy |

| ID | WBS | Task | Type | Duration | Start | Finish | Predecessors | Total slack | Free slack | Resources | Work | Text1 |
| --- | --- | --- | --- | --- | --- | --- | --- | --- | --- | --- | --- | --- |
| 533 | 1.4.1.2.3.3 | **Complete Organization Design** |  | 125.95d | 2007-01-19 | 2007-07-16 |  | 347.46d |  |  | 1054.8h |  |
| 534 | 1.4.1.2.3.3.1 | **Develop Unit-Level Structures** |  | 76.6d | 2007-01-19 | 2007-05-08 |  | 347.46d |  |  | 564.8h |  |
| 535 | 1.4.1.2.3.3.1.1 | Validate "to be" workflows |  | 4d | 2007-01-19 | 2007-01-25 | 404 | 347.46d | 0d |  |  | Kathy |
| 536 | 1.4.1.2.3.3.1.2 | Define and Develop Unit Level Roles |  | 36d | 2007-01-25 | 2007-03-16 | 535 | 347.46d | 0d | Operations Manager | 288h | Kathy, Rob |
| 537 | 1.4.1.2.3.3.1.3 | Confirm Process Responsibilities and Accountability |  | 5.4d | 2007-03-16 | 2007-03-26 | 536 | 347.46d | 0d | Operations Manager | 43.2h | Kathy, Rob |
| 538 | 1.4.1.2.3.3.1.4 | Preliminary Performance Measures |  | 10.2d | 2007-03-26 | 2007-04-09 | 537 | 347.46d | 0d | Operations Manager | 81.6h | Operations Manager |
| 539 | 1.4.1.2.3.3.1.5 | Develop Competencies and Position Descriptions (PDQs) |  | 14d | 2007-04-09 | 2007-04-27 | 538 | 347.46d | 0d | Operations Manager | 112h | Operations Manager |
| 540 | 1.4.1.2.3.3.1.6 | Define skill gaps & additional training needs |  | 5d | 2007-04-27 | 2007-05-04 | 539 | 347.46d | 0d | Operations Manager | 40h | HR Support,Operations Manager |
| 541 | 1.4.1.2.3.3.1.7 | Validate with Team and Steering Committee |  | 1d | 2007-05-04 | 2007-05-07 | 540 | 347.46d | 0d |  |  |  |
| 542 | 1.4.1.2.3.3.1.8 | Obtain Approval |  | 1d | 2007-05-07 | 2007-05-08 | 541 | 347.46d | 0d |  |  |  |
| 543 | 1.4.1.2.3.3.2 | **HR Policy Amendments** |  | 10d | 2007-05-08 | 2007-05-22 |  | 386.81d |  |  |  |  |
| 544 | 1.4.1.2.3.3.2.1 | Review HR Policies |  | 2d | 2007-05-08 | 2007-05-10 | 542 | 386.81d | 0d |  |  | Kathy, HR |
| 545 | 1.4.1.2.3.3.2.2 | Identify Impacts and Changes Required |  | 2d | 2007-05-10 | 2007-05-14 | 544 | 386.81d | 0d |  |  | Kathy, HR |
| 546 | 1.4.1.2.3.3.2.3 | Examine Career Management Issues, Paths |  | 2d | 2007-05-14 | 2007-05-16 | 545 | 386.81d | 0d |  |  | Kathy, HR |
| 547 | 1.4.1.2.3.3.2.4 | Validate Changes and Obtain Approval |  | 1d | 2007-05-16 | 2007-05-17 | 546 | 386.81d | 0d |  |  |  |
| 548 | 1.4.1.2.3.3.2.5 | **Align Performance Mgmt Systems** |  | 3d | 2007-05-17 | 2007-05-22 |  | 386.81d |  |  |  |  |
| 549 | 1.4.1.2.3.3.2.5.1 | Review Current Perf. Mgmt Systems |  | 1d | 2007-05-17 | 2007-05-18 | 547 | 386.81d | 0d |  |  | HR |
| 550 | 1.4.1.2.3.3.2.5.2 | Determine GAPs |  | 1d | 2007-05-18 | 2007-05-21 | 549 | 386.81d | 0d |  |  | HR |
| 551 | 1.4.1.2.3.3.2.5.3 | Determine Alignment Strategies |  | 1d | 2007-05-21 | 2007-05-22 | 550 | 386.81d |  |  |  | HR |
| 552 | 1.4.1.2.3.3.3 | **Compensation Design** |  | 23.4d | 2007-05-08 | 2007-06-08 |  | 373.41d |  |  | 91.2h |  |
| 553 | 1.4.1.2.3.3.3.1 | Conduct Job Evaluations |  | 8d | 2007-05-08 | 2007-05-18 | 542 | 373.41d | 0d |  |  | HR |
| 554 | 1.4.1.2.3.3.3.2 | Benchmark to External Sources |  | 1d | 2007-05-18 | 2007-05-21 | 553 | 373.41d | 0d |  |  | Kathy |
| 555 | 1.4.1.2.3.3.3.3 | Develop and Review Corporate Framework and Principles |  | 2d | 2007-05-21 | 2007-05-23 | 554 | 373.41d | 0d |  |  | HR |
| 556 | 1.4.1.2.3.3.3.4 | Define Compensation Strategy |  | 11.4d | 2007-05-23 | 2007-06-07 | 555 | 373.41d | 0d | Operations Manager | 91.2h | HR, Rob |
| 557 | 1.4.1.2.3.3.3.5 | Obtain Approval |  | 1d | 2007-06-07 | 2007-06-08 | 556 | 373.41d | 0d |  |  |  |
| 558 | 1.4.1.2.3.3.3.6 | Implement Changes - Ongoing | milestone | 0d | 2007-06-08 | 2007-06-08 | 557 | 373.41d |  |  |  |  |

| ID | WBS | Task | Duration | Start | Finish | Predecessors | Total slack | Free slack | Constraint | Resources | Work | Text1 |
| --- | --- | --- | --- | --- | --- | --- | --- | --- | --- | --- | --- | --- |
| 559 | 1.4.1.2.3.3.4 | **Recruitment Strategy** | 17.5d | 2007-05-08 | 2007-05-31 |  | 379.31d |  |  |  | 132h |  |
| 560 | 1.4.1.2.3.3.4.1 | Develop Strategy | 16.5d | 2007-05-08 | 2007-05-30 | 542 | 379.31d | 0d |  | Operations Manager | 132h | HR, Kathy |
| 561 | 1.4.1.2.3.3.4.2 | Implement Strategy | 1d | 2007-05-30 | 2007-05-31 | 560 | 379.31d |  |  |  |  | HR |
| 562 | 1.4.1.2.3.3.5 | **Staff Retention/Redeployment, Transition and Migration** | 49.35d | 2007-05-08 | 2007-07-16 |  | 347.46d |  |  |  | 266.8h |  |
| 563 | 1.4.1.2.3.3.5.1 | Determine and confirm positions by region | 6.45d | 2007-05-08 | 2007-05-16 | 542 | 347.46d | 0d |  | Operations Manager | 51.6h | Rob |
| 564 | 1.4.1.2.3.3.5.2 | **Develop Migration Strategy** | 10d | 2007-05-16 | 2007-05-30 |  | 347.46d | 0d |  |  |  |  |
| 565 | 1.4.1.2.3.3.5.2.1 | Timing | 2d | 2007-05-16 | 2007-05-18 | 563 | 347.46d | 0d |  |  |  | Lori |
| 566 | 1.4.1.2.3.3.5.2.2 | Principles | 2d | 2007-05-18 | 2007-05-22 | 565 | 347.46d | 0d |  |  |  | Lori |
| 567 | 1.4.1.2.3.3.5.2.3 | Policies | 2d | 2007-05-22 | 2007-05-24 | 566 | 347.46d | 0d |  |  |  | Lori |
| 568 | 1.4.1.2.3.3.5.2.4 | Adjustment Measures | 2d | 2007-05-24 | 2007-05-28 | 567 | 347.46d | 0d |  |  |  | Lori |
| 569 | 1.4.1.2.3.3.5.2.5 | Recruitment/Support | 2d | 2007-05-28 | 2007-05-30 | 568 | 347.46d |  |  |  |  | Lori |
| 570 | 1.4.1.2.3.3.5.3 | Confirm Strategy | 4.3d | 2007-05-30 | 2007-06-05 | 564 | 347.46d | 0d |  | Operations Manager | 34.4h | Lori |
| 571 | 1.4.1.2.3.3.5.4 | Validation with Key Staff and Incorporate Feedback | 8.6d | 2007-06-05 | 2007-06-18 | 570 | 347.46d | 0d |  | Operations Manager | 68.8h | Rob, Branch Mgr |
| 572 | 1.4.1.2.3.3.5.5 | Obtain Approval on Strategy | 1d | 2007-06-18 | 2007-06-19 | 571 | 347.46d | 0d |  |  |  |  |
| 573 | 1.4.1.2.3.3.5.6 | Discuss Transition Options with All Affected Staff | 14d | 2007-06-19 | 2007-07-09 | 572 | 347.46d | 0d |  | Operations Manager | 112h | Rob, Branch Mgr |
| 574 | 1.4.1.2.3.3.5.7 | Provide Support to Staff and Managers | 5d | 2007-07-09 | 2007-07-16 | 573 | 347.46d |  |  |  |  | Lori |
| 575 | 1.4.1.2.3.4 | **Implement Communication Strategy and Plan** | 148d | 2007-01-01 | 2007-07-25 |  | 340.03d |  |  |  |  |  |
| 576 | 1.4.1.2.3.4.1 | **Ongoing Communications** | 148d | 2007-01-01 | 2007-07-25 |  | 340.03d |  |  |  |  |  |
| 577 | 1.4.1.2.3.4.1.1 | **Newsletters** | 148d | 2007-01-01 | 2007-07-25 |  | 340.03d |  |  |  |  |  |
| 578 | 1.4.1.2.3.4.1.1.1 | Newsletters - 1 | 12d | 2007-01-01 | 2007-01-16 |  | 340.03d | 0d | start no earlier than 2007-01-01 |  |  | Communications |
| 579 | 1.4.1.2.3.4.1.1.2 | Newsletters - 2 | 12d | 2007-02-28 | 2007-03-15 | 578FS+30d | 340.03d | 0d |  |  |  | Communications |
| 580 | 1.4.1.2.3.4.1.1.3 | Newsletters - 3 | 12d | 2007-04-27 | 2007-05-14 | 579FS+30d | 340.03d | 0d |  |  |  | Communications |
| 581 | 1.4.1.2.3.4.1.1.4 | Newsletters - 4 | 12d | 2007-07-10 | 2007-07-25 | 580FS+40d | 340.03d |  |  |  |  | Communications |
| 582 | 1.4.1.2.3.4.1.2 | Fact Sheets - By Milestones | 30d | 2007-01-01 | 2007-02-09 |  | 458.03d |  |  |  |  | Communications |
| 583 | 1.4.1.2.3.4.1.3 | E-mails/Voice-Mails | 30d | 2007-01-01 | 2007-02-09 |  | 458.03d |  |  |  |  | Communications |
| 584 | 1.4.1.2.3.4.1.4 | Ongoing unscheduled communication activities (includes <dept>) | 22.18d | 2007-01-01 | 2007-01-31 |  | 465.85d |  |  |  |  | Kathy |
| 585 | 1.4.1.2.3.4.1.5 | Formal Information Sessions | 12d | 2007-01-01 | 2007-01-16 |  | 476.03d |  |  |  |  | Kathy, Lori |
| 586 | 1.4.1.2.3.4.1.6 | Ongoing - Coaching to Mgmt to Support Staff Communications | 10d | 2007-01-01 | 2007-01-12 |  | 478.03d |  |  |  |  | Kathy |
| 587 | 1.4.1.2.3.4.1.7 | Assess Feedback - Ongoing | 12d | 2007-01-01 | 2007-01-16 |  | 476.03d |  |  |  |  | Lori, Kathy |

| ID | WBS | Task | Duration | Start | Finish | Predecessors | Total slack | Free slack | Resources | Work | Text1 |
| --- | --- | --- | --- | --- | --- | --- | --- | --- | --- | --- | --- |
| 588 | 1.4.1.2.3.5 | **Ongoing - Change Mgmt Project Team Monitoring & Reporting Tasks** | 18d | 2007-01-01 | 2007-01-24 |  | 470.03d |  |  |  |  |
| 589 | 1.4.1.2.3.5.1 | Lessons Learned - after every Major Milestones | 4.36d | 2007-01-01 | 2007-01-05 |  | 483.68d |  |  |  |  |
| 590 | 1.4.1.2.3.5.2 | Communicate and monitor team member change mgmt tasks | 10d | 2007-01-01 | 2007-01-12 |  | 478.03d |  |  |  | Kathy |
| 591 | 1.4.1.2.3.5.3 | Monitor Project Team Effectiveness | 13.91d | 2007-01-01 | 2007-01-18 |  | 474.12d |  |  |  | Kathy |
| 592 | 1.4.1.2.3.5.4 | Celebrations | 4.2d | 2007-01-01 | 2007-01-05 |  | 483.83d |  |  |  |  |
| 593 | 1.4.1.2.3.5.5 | Ongoing coaching to project team, extended team, management | 5d | 2007-01-01 | 2007-01-05 |  | 483.03d |  |  |  | Kathy |
| 594 | 1.4.1.2.3.5.6 | Monitor Effectiveness of Change | 10d | 2007-01-01 | 2007-01-12 |  | 478.03d |  |  |  | Kathy |
| 595 | 1.4.1.2.3.5.7 | Track & communicate people & org issues | 18d | 2007-01-01 | 2007-01-24 |  | 470.03d |  |  |  | Kathy |
| 596 | 1.4.1.2.3.5.8 | Monitor Decision Making process | 9d | 2007-01-01 | 2007-01-11 |  | 479.03d |  |  |  | Rick |
| 597 | 1.4.1.2.3.6 | **Sustainment Readiness** | 54.2d | 2007-05-01 | 2007-07-16 |  | 347.28d |  |  |  |  |
| 598 | 1.4.1.2.3.6.1 | Define re-entry strategy for Team | 7.8d | 2007-05-01 | 2007-05-11 | 429 | 347.28d | 0d |  |  | Rob, Kathy |
| 599 | 1.4.1.2.3.6.2 | Confirm Understanding of roles, responsibilities, etc. | 42d | 2007-05-11 | 2007-07-10 | 598 | 347.28d | 0d |  |  | Kathy |
| 600 | 1.4.1.2.3.6.3 | Develop ongoing post implementation evaluation plan and mechanisms | 4.4d | 2007-07-10 | 2007-07-16 | 599 | 347.28d |  |  |  | Rob |
| 601 | 1.4.1.2.4 | **User Procedures and Training** | 94.27d | 2007-01-01 | 2007-05-11 |  | 393.76d |  |  | 570.4h |  |
| 602 | 1.4.1.2.4.1 | **Determine Procedures Strategy** | 10.65d | 2007-01-04 | 2007-01-19 |  | 393.76d |  |  | 72.4h |  |
| 603 | 1.4.1.2.4.1.1 | Identify Target Audiences for Documentation | 1d | 2007-01-04 | 2007-01-05 | 427 | 393.76d | 0d | Business SME [85%] | 6.8h | Business SME |
| 604 | 1.4.1.2.4.1.2 | Determine Documentation Needs by Target Audience(s) | 3.35d | 2007-01-05 | 2007-01-10 | 603 | 393.76d | 0d | Business SME [85%] | 22.8h | Business SME |
| 605 | 1.4.1.2.4.1.3 | Determine High-Priority Areas | 1.94d | 2007-01-10 | 2007-01-12 | 604 | 393.76d | 0d | Business SME [85%] | 13.2h | Business SME |
| 606 | 1.4.1.2.4.1.4 | Determine Roles and Responsibilities | 2.18d | 2007-01-12 | 2007-01-16 | 605 | 393.76d | 0d | Business SME [85%] | 14.8h | Business SME |
| 607 | 1.4.1.2.4.1.5 | Develop Strategy and Plan | 2.18d | 2007-01-16 | 2007-01-19 | 606 | 393.76d | 0d | Business SME [85%] | 14.8h | Business SME |
| 608 | 1.4.1.2.4.2 | **Develop Standard Operating Procedures** | 51.27d | 2007-01-19 | 2007-04-02 |  | 422.62d |  |  | 368.4h |  |
| 609 | 1.4.1.2.4.2.1 | Prepare Table of Contents | 1d | 2007-01-19 | 2007-01-22 | 607 | 422.62d | 0d | Business SME [85%] | 6.8h | Business SME |
| 610 | 1.4.1.2.4.2.2 | Prepare Document Introduction & Overview | 2d | 2007-01-22 | 2007-01-24 | 609 | 422.62d | 0d | Business SME [85%] | 13.6h | Business SME |
| 611 | 1.4.1.2.4.2.3 | Prepare User Procedures | 36.47d | 2007-01-24 | 2007-03-15 | 610 | 422.62d | 0d | Business SME [85%] | 248h | Business SME |
| 612 | 1.4.1.2.4.2.4 | Sample Completed Forms | 2d | 2007-03-15 | 2007-03-19 | 611 | 422.62d | 0d | Business SME [85%] | 13.6h | Business SME |
| 613 | 1.4.1.2.4.2.5 | Review Procedures | 10.8d | 2007-03-15 | 2007-03-30 | 612FS-2d | 422.62d | 0d | Operations Manager | 86.4h | Business SME |
| 614 | 1.4.1.2.4.2.6 | Obtain Approval on User Procedures | 1d | 2007-03-30 | 2007-04-02 | 613 | 422.62d |  |  |  |  |

| ID | WBS | Task | Type | Duration | Start | Finish | Predecessors | Complete | Remaining | Total slack | Free slack | Resources | Work | Text1 |
| --- | --- | --- | --- | --- | --- | --- | --- | --- | --- | --- | --- | --- | --- | --- |
| 615 | 1.4.1.2.4.3 | **Training** |  | 94.27d | 2007-01-01 | 2007-05-11 |  |  |  | 393.76d | 0d |  | 129.6h |  |
| 616 | 1.4.1.2.4.3.1 | **Develop detailed training strategy and plan** |  | 11.91d | 2007-01-19 | 2007-02-06 |  |  |  | 393.76d |  |  |  |  |
| 617 | 1.4.1.2.4.3.1.1 | **Conduct Needs Assessment** |  | 11.91d | 2007-01-19 | 2007-02-06 |  |  |  | 393.76d |  |  |  |  |
| 618 | 1.4.1.2.4.3.1.1.1 | Determine User Population and Analysis |  | 1.98d | 2007-01-19 | 2007-01-23 | 607 |  |  | 393.76d | 0d |  |  | Martin |
| 619 | 1.4.1.2.4.3.1.1.2 | Identify User Training Philosophy and Approach |  | 1.98d | 2007-01-23 | 2007-01-25 | 618 |  |  | 393.76d | 0d |  |  | Martin |
| 620 | 1.4.1.2.4.3.1.1.3 | Determine High-Priority Areas |  | 1.98d | 2007-01-25 | 2007-01-29 | 619 |  |  | 393.76d | 0d |  |  | Martin |
| 621 | 1.4.1.2.4.3.1.1.4 | Determine Roles and Responsibilities |  | 1.98d | 2007-01-29 | 2007-01-31 | 620 |  |  | 393.76d | 0d |  |  | Martin |
| 622 | 1.4.1.2.4.3.1.1.5 | Revise Plan based on Needs Assessment |  | 4d | 2007-01-31 | 2007-02-06 | 621 |  |  | 393.76d | 0d |  |  | Rick |
| 623 | 1.4.1.2.4.3.2 | **Develop Training Course Materials** |  | 68.21d | 2007-02-06 | 2007-05-11 |  |  |  | 393.76d |  |  | 129.6h |  |
| 624 | 1.4.1.2.4.3.2.1 | Determine learning objectives for each course and course module |  | 8.52d | 2007-02-06 | 2007-02-16 | 622 |  |  | 393.76d | 0d |  |  | Martin |
| 625 | 1.4.1.2.4.3.2.2 | Prepare Student Materials |  | 26.44d | 2007-02-16 | 2007-03-27 | 624 |  |  | 393.76d | 0d |  |  | Martin, Bonnie |
| 626 | 1.4.1.2.4.3.2.3 | Prepare Application-Specific Training Exercises |  | 17.05d | 2007-03-27 | 2007-04-19 | 625 |  |  | 393.76d | 0d |  |  | Bonnie |
| 627 | 1.4.1.2.4.3.2.4 | Review Materials |  | 16.2d | 2007-04-19 | 2007-05-11 | 626 |  |  | 393.76d | 0d | Operations Manager | 129.6h |  |
| 628 | 1.4.1.2.4.3.2.5 | Obtain Approval on Training Approach & Materials | milestone | 0d | 2007-05-11 | 2007-05-11 | 627 |  |  | 393.76d |  |  |  |  |
| 629 | 1.4.1.2.4.3.3 | **Training Environment** |  | 2.92d | 2007-01-01 | 2007-01-03 |  |  |  | 485.11d |  |  |  |  |
| 630 | 1.4.1.2.4.3.3.1 | Confirm training installation strategy |  | 0.93d | 2007-01-01 | 2007-01-01 |  |  |  | 485.11d | 0d |  |  | Bonnie |
| 631 | 1.4.1.2.4.3.3.2 | Prepare training environment |  | 2d | 2007-01-01 | 2007-01-03 | 630 |  |  | 485.11d |  |  |  | Lois |
| 632 | 1.4.1.2.4.3.4 | Deliver Training |  | 1d | 2007-01-01 | 2007-01-01 |  |  |  | 487.03d |  |  |  |  |
| 633 | 1.4.1.3 | **Development Track** |  | 64d | 2007-01-01 A | 2007-03-29 |  | 2% | 62.44d | 424.03d |  |  | 494.4h | Ba |
| 634 | 1.4.1.3.1 | **Information Requirement Planning** |  | 10.2d | 2007-01-01 | 2007-01-15 |  |  |  | 477.83d |  |  | 14.4h |  |
| 635 | 1.4.1.3.1.1 | **Strategies** |  | 9.2d | 2007-01-01 | 2007-01-12 |  |  |  | 477.83d |  |  | 14.4h |  |
| 636 | 1.4.1.3.1.1.1 | **Revise High-Level Strategies (Interface,Conversion etc.)** |  | 4d | 2007-01-01 | 2007-01-04 |  |  |  | 483.03d | 0d |  |  |  |
| 637 | 1.4.1.3.1.1.1.1 | Conversion Strategy |  | 2d | 2007-01-01 | 2007-01-02 |  |  |  | 483.03d | 0d |  |  |  |
| 638 | 1.4.1.3.1.1.1.2 | Interface Strategy |  | 2d | 2007-01-03 | 2007-01-04 | 637 |  |  | 483.03d |  |  |  |  |

| ID | WBS | Task | Type | Duration | Start | Finish | Predecessors | Complete | Remaining | Total slack | Free slack | Constraint | Resources | Work | Text1 | Text30 | Text2 | Text10 |
| --- | --- | --- | --- | --- | --- | --- | --- | --- | --- | --- | --- | --- | --- | --- | --- | --- | --- | --- |
| 639 | 1.4.1.3.1.1.2 | **Develop strategies for Reports, Workflows, etc.** |  | 8.2d | 2007-01-01 | 2007-01-11 |  |  |  | 477.83d |  |  |  | 14.4h |  |  |  |  |
| 640 | 1.4.1.3.1.1.2.1 | Determine current reports metrics |  | 1d | 2007-01-01 | 2007-01-01 |  |  |  | 477.83d | 0d |  |  |  | Craig |  |  |  |
| 641 | 1.4.1.3.1.1.2.2 | Assess Current Reports |  | 4.4d | 2007-01-02 | 2007-01-08 | 640 |  |  | 477.83d | 0d |  |  |  | Sue |  |  |  |
| 642 | 1.4.1.3.1.1.2.3 | Develop Reporting Strategy |  | 1.8d | 2007-01-08 | 2007-01-10 | 641 |  |  | 477.83d | 0d |  | Business SME | 14.4h |  |  |  |  |
| 643 | 1.4.1.3.1.1.2.4 | Identify Customizations (Workflow, Alerts, etc.) |  | 1d | 2007-01-10 | 2007-01-11 | 642 |  |  | 477.83d | 0d |  |  |  | Ba |  |  |  |
| 644 | 1.4.1.3.1.1.3 | Obtain Approval on Technical Integration Strategies/High-Level Requirements |  | 1d | 2007-01-11 | 2007-01-12 | 643 |  |  | 477.83d | 0d |  |  |  |  |  |  |  |
| 645 | 1.4.1.3.1.2 | Refine Plan |  | 1d | 2007-01-12 | 2007-01-15 | 644 |  |  | 477.83d |  |  |  |  | Rick |  |  |  |
| 646 | 1.4.1.3.2 | **Data Conversion Management** |  | 43.2d | 2007-01-01 A | 2007-03-01 |  | 9% | 39.11d | 444.83d |  |  |  | 40h |  | AR |  |  |
| 647 | 1.4.1.3.2.1 | Confirm Deliverable Templates |  | 1d | 2007-01-05 | 2007-01-05 | 636 |  |  | 483.03d | 0d | start no earlier than 2007-01-01 |  |  | Ba | AR |  |  |
| 648 | 1.4.1.3.2.2 | **Design Conversions** |  | 5d | 2007-01-01 | 2007-01-05 |  |  |  | 483.03d |  |  |  |  |  | AR | Conversion Specs. |  |
| 649 | 2.2.1.4 | Confirm Hardware Sizing and Software Requirements with the Infrastructure team | milestone | 0d | 2007-01-05 | 2007-01-05 | 647 |  |  | 483.03d |  |  |  |  | Ba | AR |  | ORA02090104.htm |
| 650 | 2.2.1.9 | Develop overall Conversion plan & dependencies, trial runs |  | 1.07d | 2007-01-01 | 2007-01-02 |  |  |  | 486.96d |  |  |  |  | Ba | AR |  |  |
| 651 | 1.4.1.3.2.3 | **Existing Data Cleanup- Define Manual Procedures** |  | 1d | 2007-01-01 | 2007-01-01 |  |  |  | 487.03d |  |  |  |  |  |  |  |  |
| 652 | 1.4.1.3.2.3.1 | Move to cutover - Confirm data from legacy systems has been cleansed |  | 1d | 2007-01-01 | 2007-01-01 |  |  |  | 487.03d |  |  |  |  | Lois |  |  |  |
| 653 | 2.2.2 | **Build Conversion Programs** |  | 43.2d | 2007-01-01 A | 2007-03-01 |  | 14% | 37.24d | 444.83d |  |  |  |  |  | AR |  | ORA02090200.htm |
| 654 | 2.2.2.4 | Develop Code Conversions |  | 43.2d | 2007-01-01 A | 2007-03-01 |  | 14% | 37.2d | 444.83d |  |  |  |  |  | AR |  | ORA02090204.htm |
| 655 | 1.4.1.3.2.4.2 | Develop Code Extracts |  | 0.94d | 2007-01-01 A | 2007-01-01 |  | 9% | 0.85d | 487.1d |  |  |  |  |  | AR |  |  |
| 656 | 2.2.2.5 | Execute Unit Test |  | 7d | 2007-01-01 | 2007-01-09 |  |  |  | 471.03d | 0d |  |  |  |  | AR | Unit Test Results | ORA02090205.htm |
| 657 | 1.4.1.3.2.6 | **Correct Program Errors Based on Unit Test Results** |  | 6d | 2007-01-10 | 2007-01-17 |  |  |  | 471.03d |  |  |  | 40h |  | AR |  |  |
| 658 | 2.2.2.8 | Correct Design/Program Errors, Review, and Test based on Unit Test Results |  | 5d | 2007-01-10 | 2007-01-16 | 656 |  |  | 471.03d | 0d |  | Legacy Developer | 40h |  | AR |  | ORA02090208.htm |
| 659 | 2.2.2.11 | Prepare for Integration Testing |  | 1d | 2007-01-17 | 2007-01-17 | 658 |  |  | 471.03d | 0d |  |  |  | Joe | AR |  | ORA02090211.htm |
| 660 | 2.2.3 | **Implement Feedback from Integration Testing** |  | 3d | 2007-01-18 | 2007-01-22 |  |  |  | 471.03d |  |  |  |  |  | AR |  | ORA02090300.htm |
| 661 | 2.2.3.2 | Complete documentation |  | 3d | 2007-01-18 | 2007-01-22 | 659 |  |  | 471.03d | 0d |  |  |  | Tracey, Les | AR |  | ORA02090302.htm |
| 662 | 2.2.4 | **Prepare for Cutover** |  | 1d | 2007-01-23 | 2007-01-23 |  |  |  | 471.03d |  |  |  |  |  | AR |  | ORA02090400.htm |
| 663 | 2.2.4.1 | Provide Conversion information regarding DB Sizing |  | 1d | 2007-01-23 | 2007-01-23 | 661 |  |  | 471.03d |  |  |  |  | Joe | AR |  | ORA02090401.htm |

| ID | WBS | Task | Duration | Start | Finish | Predecessors | Total slack | Free slack | Constraint | Work | Text30 | Text10 | Text1 | Text2 |
| --- | --- | --- | --- | --- | --- | --- | --- | --- | --- | --- | --- | --- | --- | --- |
| 664 | 1.4.1.3.3 | **Custom Code Interfaces, Extensions, and Bolt-ons Design/Build** | 64d | 2007-01-01 | 2007-03-29 |  | 109.03d |  |  | 440h | AR |  |  |  |
| 665 | 2.3.1 | **Refine the Requirements for Interfaces, Extensions, and Bolt-on** | 1d | 2007-01-05 | 2007-01-05 |  | 483.03d |  |  |  | AR | ORA02100100.htm |  |  |
| 666 | 1.4.1.3.3.1.1 | Confirm Deliverable Templates | 0.5d | 2007-01-05 | 2007-01-05 | 636 | 483.03d | 0d |  |  | AR |  | Ba |  |
| 667 | 2.3.1.1 | Confirm Scope for Interfaces, Extensions, and Bolt-ons | 0.5d | 2007-01-05 | 2007-01-05 | 666 | 483.03d |  |  |  | AR | ORA02100101.htm | Rick |  |
| 668 | 1.4.1.3.3.2 | **Interfaces** | 6d | 2007-01-01 | 2007-01-08 |  | 109.03d |  |  |  | AR |  |  |  |
| 669 | 1.4.1.3.3.2.1 | **Design (Functional)** | 3.2d | 2007-01-01 | 2007-01-04 |  | 484.83d |  |  |  | AR |  |  |  |
| 670 | 2.3.2.1 | Document Procedures (Include Exceptions) | 1d | 2007-01-01 | 2007-01-01 |  | 484.83d | 0d |  |  | AR | ORA02100201.htm | Lois, Tracey |  |
| 671 | 1.5.1.3.3.2.1.1.7 | Review Design and Conduct Walkthroughs | 1.2d | 2007-01-02 | 2007-01-03 | 670 | 484.83d | 0d |  |  |  |  | Tracey, Ba |  |
| 672 | 1.5.1.3.3.2.1.1.8 | Obtain Approval on Design - Oracle & CIF & Legacy | 1d | 2007-01-03 | 2007-01-04 | 671 | 484.83d |  |  |  | AR |  |  |  |
| 673 | 1.4.1.3.3.2.2 | **Build (Includes Technical Design)** | 1d | 2007-01-01 | 2007-01-01 |  | 487.03d |  |  |  | AR |  |  |  |
| 674 | 2.3.2.5 | Ongoing - Review code for Standards, Logic, and Performance | 1d | 2007-01-01 | 2007-01-01 |  | 487.03d |  |  |  | AR | ORA02100205.htm | Ba |  |
| 675 | 2.3.2.6 | **Execute Unit Test (includes scripts)** | 2d | 2007-01-01 | 2007-01-02 |  | 484.03d | 0d |  |  | AR | ORA02100206.htm |  | Unit Test Results |
| 676 | 1.4.1.3.3.2.3.1 | Control Programs | 2d | 2007-01-01 | 2007-01-02 |  | 484.03d |  |  |  |  |  | Tracey, Joe |  |
| 677 | 2.3.2.8 | Release into functional testing and review | 1d | 2007-01-01 | 2007-01-01 |  | 487.03d |  |  |  | AR | ORA02100208.htm |  |  |
| 678 | 2.3.4 | **Release into System Testing** | 1d | 2007-01-01 | 2007-01-01 |  | 109.03d |  |  |  | AR | ORA02100400.htm |  |  |
| 679 | 2.3.4.1 | Release into a change controlled environment | 1d | 2007-01-01 | 2007-01-01 |  | 109.03d | 0d |  |  | AR | ORA02100401.htm | Joe |  |
| 680 | 2.3.4.2 | Complete documentation | 5d | 2007-01-02 | 2007-01-08 | 679 | 482.03d |  |  |  | AR | ORA02100402.htm | Tracey |  |
| 681 | 1.4.1.3.3.3 | **Customizations (includes reports, alerts, workflows, etc.)** | 64d | 2007-01-01 | 2007-03-29 |  | 424.03d |  |  | 440h | AR |  |  |  |
| 682 | 1.4.1.3.3.3.1 | **Design** | 64d | 2007-01-01 | 2007-03-29 |  | 424.03d |  |  |  | AR |  |  |  |
| 683 | 1.4.1.3.3.3.1.1 | **Reports** | 64d | 2007-01-01 | 2007-03-29 |  | 424.03d |  |  |  | AR |  |  |  |
| 684 | 1.4.1.3.3.3.1.1.1 | Dunning Letters | 6d | 2007-01-01 | 2007-01-08 |  | 482.03d |  | start no earlier than 2007-01-01 |  |  |  | Brad |  |
| 685 | 1.4.1.3.3.3.1.1.2 | AR Reconciliation | 64d | 2007-01-01 | 2007-03-29 |  | 424.03d |  |  |  |  |  | Brad |  |
| 686 | 1.4.1.3.3.3.1.1.3 | Modifications to Std Reports | 5d | 2007-01-01 | 2007-01-05 |  | 476.03d | 0d |  |  | AR |  | Brad |  |
| 687 | 1.4.1.3.3.3.1.2 | Alerts and Workflow | 7d | 2007-01-08 | 2007-01-16 | 686 | 476.03d |  |  |  | AR |  | Brad |  |

| ID | WBS | Task | Duration | Start | Finish | Predecessors | Total slack | Free slack | Constraint | Resources | Work | Text30 | Text1 | Text2 | Text10 |
| --- | --- | --- | --- | --- | --- | --- | --- | --- | --- | --- | --- | --- | --- | --- | --- |
| 688 | 1.4.1.3.3.3.2 | **Build** | 25d | 2007-01-01 | 2007-02-02 |  | 450.83d |  |  |  | 360h | AR |  |  |  |
| 689 | 1.4.1.3.3.3.2.1 | **Reports** | 25d | 2007-01-01 | 2007-02-02 |  | 450.83d |  |  |  | 280h | AR |  |  |  |
| 690 | 1.4.1.3.3.3.2.1.1 | Dunning Letters | 10d | 2007-01-22 | 2007-02-02 | 691 | 450.83d | 0d |  | Reports Developer | 80h |  | Reports Developer |  |  |
| 691 | 1.4.1.3.3.3.2.1.2 | AR Reconciliation | 15d | 2007-01-01 | 2007-01-19 |  | 450.83d | 0d |  | Reports Developer | 120h |  | Reports Developer |  |  |
| 692 | 1.4.1.3.3.3.2.1.3 | Modifications to Std Reports | 10d | 2007-01-01 | 2007-01-12 |  | 462.53d | 0d |  | Reports Developer | 80h | AR | Reports Developer |  |  |
| 693 | 1.4.1.3.3.3.2.2 | Alerts and Workflow | 10d | 2007-01-15 | 2007-01-26 | 692 | 464.18d | 0d |  | Reports Developer | 80h | AR | Reports Developer |  |  |
| 694 | 2.3.2.6 | **Execute Unit Test Plan and Document Unit Test Results** | 17.2d | 2007-01-15 | 2007-02-07 |  | 460.83d |  |  |  |  | AR |  | Unit Test Results | ORA02100206.htm |
| 695 | 1.4.1.3.3.3.3.1 | **Reports** | 17.2d | 2007-01-15 | 2007-02-07 |  | 450.83d | 0d |  |  |  | AR |  |  |  |
| 696 | 1.4.1.3.3.3.3.1.1 | Dunning Letters | 2.2d | 2007-02-05 | 2007-02-07 | 690 | 450.83d |  |  |  |  |  | Brad |  |  |
| 697 | 1.4.1.3.3.3.3.1.2 | AR Reconciliation | 2.2d | 2007-01-22 | 2007-01-24 | 691 | 460.83d |  |  |  |  |  | Brad |  |  |
| 698 | 1.4.1.3.3.3.3.1.3 | Modifications to Std Reports | 5.5d | 2007-01-15 | 2007-01-22 | 692 | 462.53d |  |  |  |  | AR | Brad |  |  |
| 699 | 1.4.1.3.3.3.3.2 | Alerts and Workflow | 3.85d | 2007-01-29 | 2007-02-01 | 693 | 464.18d |  |  |  |  | AR | Brad |  |  |
| 700 | 2.3.2.7 | Correct Program Errors Based on Unit Test Results | 10d | 2007-02-06 | 2007-02-20 | 695FS-1d | 450.83d | 0d |  | Reports Developer | 80h | AR | Reports Developer |  | ORA02100207.htm |
| 701 | 2.3.2.8 | Release into CRP for functional testing and review | 1d | 2007-02-20 | 2007-02-21 | 700 | 450.83d |  |  |  |  | AR |  |  | ORA02100208.htm |
| 702 | 2.3.4 | **Implement Feedback from CRP/Integration Testing** | 1d | 2007-02-20 | 2007-02-21 |  | 450.83d |  |  |  |  | AR |  |  | ORA02100400.htm |
| 703 | 2.3.4.1 | Release into a change controlled environment | 1d | 2007-02-20 | 2007-02-21 | 700 | 450.83d | 0d |  |  |  | AR | Joe |  | ORA02100401.htm |
| 704 | 2.3.4.2 | Complete documentation | 3d | 2007-02-14 | 2007-02-19 | 703FS-4.69d | 452.52d |  |  |  |  | AR | Brad |  | ORA02100402.htm |
| 705 | 2.3.5 | **Prepare for Cutover** | 2d | 2007-01-03 | 2007-01-04 |  | 484.03d |  |  |  |  | AR |  |  | ORA02100500.htm |
| 706 | 2.3.5.1 | Provide sizing information for Production | 1d | 2007-01-03 | 2007-01-03 | 675 | 484.03d | 0d |  |  |  | AR | Joe |  | ORA02100501.htm |
| 707 | 2.3.5.2 | Review Concurrent Managers & Job Scheduling/ Security setups | 1d | 2007-01-04 | 2007-01-04 | 706 | 484.03d |  |  |  |  | AR | Joe |  | ORA02100502.htm |
| 708 | 1.4.1.4 | **Infrastructure Technology Track** | 488.03d | 2007-01-01 | 2008-11-13 |  | 0d |  |  |  | 1800h |  |  |  |  |
| 709 | 1.4.1.4.1 | **Support Development and Establish Production Infrastructure** | 488.03d | 2007-01-01 | 2008-11-13 |  | 0d |  |  |  | 1800h |  |  |  |  |
| 710 | 1.4.1.4.1.1 | **Confirm/Revise Procedures** | 29d | 2007-01-01 | 2007-02-08 |  | 361.53d |  |  |  |  |  |  |  |  |
| 711 | 1.4.1.4.1.1.1 | Revise Instance Strategy | 2d | 2007-01-01 | 2007-01-02 |  | 361.53d | 0d | start no earlier than 2007-01-01 |  |  |  | Joe |  |  |
| 712 | 1.4.1.4.1.1.2 | Revisit Infrastructure options | 2d | 2007-01-03 | 2007-01-04 | 711 | 361.53d | 0d |  |  |  |  | Joe |  |  |
| 713 | 1.4.1.4.1.1.3 | Develop Failover options | 10d | 2007-01-05 | 2007-01-18 | 712 | 361.53d | 0d |  |  |  |  | Joe |  |  |
| 714 | 1.4.1.4.1.1.4 | Revise Budget based on infrastructure strategy | 2d | 2007-01-19 | 2007-01-22 | 713 | 459.03d | 0d |  |  |  |  | Rick |  |  |
| 715 | 1.4.1.4.1.1.1 | Migration Strategy & Procedures | 4d | 2007-01-23 | 2007-01-26 | 714 | 459.03d | 0d |  |  |  |  | Joe |  |  |
| 716 | 1.4.1.4.1.1.2 | Confirm Problem Management Procedures | 2d | 2007-01-29 | 2007-01-30 | 715 | 459.03d | 0d |  |  |  |  | Joe |  |  |
| 717 | 1.4.1.4.1.1.7 | Document Patching Strategy | 2d | 2007-01-31 | 2007-02-01 | 716 | 459.03d | 0d |  |  |  |  | Joe |  |  |
| 718 | 1.4.1.4.1.1.3 | Operational Procedures | 4d | 2007-02-02 | 2007-02-07 | 717 | 459.03d | 0d |  |  |  |  | Joe |  |  |
| 719 | 1.4.1.4.1.1.4 | Obtain Approval on Procedures | 1d | 2007-02-08 | 2007-02-08 | 718 | 459.03d |  |  |  |  |  |  |  |  |

| ID | WBS | Task | Type | Duration | Start | Finish | Predecessors | Total slack | Free slack | Resources | Work | Text1 |
| --- | --- | --- | --- | --- | --- | --- | --- | --- | --- | --- | --- | --- |
| 720 | 1.4.1.4.1.2 | **Install New Instances (Based on Instance Strategy)** |  | 474.03d | 2007-01-19 | 2008-11-13 |  | 0d |  |  | 1800h |  |
| 721 | 1.4.1.4.1.2.3 | System/Integration Testing |  | 3d | 2008-09-10 | 2008-09-15 | 795FS-45d | 43d |  |  |  | Joe |
| 722 | 1.4.1.4.1.2.4 | Stress Testing |  | 3d | 2007-05-23 | 2007-05-28 | 821FS-35d | 641.85d |  |  |  | Joe |
| 723 | 1.4.1.4.1.2.5 | Training |  | 3d | 2007-04-13 | 2007-04-18 | 615FS-20d | 670.56d |  |  |  | Joe |
| 724 | 1.4.1.4.1.2.4 | Build Failover Architecture - HW |  | 112.5d | 2007-01-19 | 2007-06-26 | 713 | 361.53d |  | Server Admin; Network Support | 1800h | Joe |
| 725 | 1.4.1.4.1.2.6 | Production - Apply Patches |  | 5d | 2008-11-06 | 2008-11-13 | 798FS-4d | 0d |  |  |  | Joe |
| 726 | 1.4.1.4.1.3 | **Ongoing Support for Design/Build Stage** |  | 0.12d | 2007-01-01 | 2007-01-01 |  | 487.91d |  |  |  |  |
| 727 | 1.4.1.4.1.3.1 | Ongoing DBA Support |  | 0.12d | 2007-01-01 | 2007-01-01 |  | 747.71d |  |  |  | Joe |
| 728 | 1.4.1.4.1.3.1.1 | Change Control Mgmt (Appl/ Data Migration) | milestone | 0d | 2007-01-01 | 2007-01-01 |  | 747.83d |  |  |  |  |
| 729 | 1.4.1.4.1.3.1.2 | Application of Patches (Application, RDMBS, etc.) | milestone | 0d | 2007-01-01 | 2007-01-01 |  | 747.83d |  |  |  |  |
| 730 | 1.4.1.4.1.3.1.3 | Database Administration, Monitoring and Sizing | milestone | 0d | 2007-01-01 | 2007-01-01 |  | 747.83d |  |  |  |  |
| 731 | 1.4.1.4.1.3.1.4 | Data Imports, Exports, Back-Up, Refresh Instances | milestone | 0d | 2007-01-01 | 2007-01-01 |  | 747.83d |  |  |  |  |
| 732 | 1.4.1.4.1.3.2 | Ongoing Server Admin Skills | milestone | 0d | 2007-01-01 | 2007-01-01 |  | 747.83d |  |  |  |  |
| 733 | 1.4.1.4.1.3.3 | Ongoing System Admin Support | milestone | 0d | 2007-01-01 | 2007-01-01 |  | 747.83d |  |  |  |  |
| 734 | 1.4.1.4.1.3.4 | Ongoing Tech. Infrastructure (Network, Printers, etc.) Support | milestone | 0d | 2007-01-01 | 2007-01-01 |  | 747.83d |  |  |  |  |
| 735 | 1.4.1.4.1.4 | **Transition to Production** |  | 13.5d | 2008-10-15 | 2008-11-03 |  | 2.5d |  |  |  |  |
| 736 | 1.4.1.4.1.4.2 | **Confirm Production Environment** |  | 5d | 2008-10-15 | 2008-10-22 |  | 2.5d |  |  |  |  |
| 737 | 1.4.1.4.1.4.2.1 | Confirm Production Environment Requirements |  | 0.5d | 2008-10-15 | 2008-10-15 | 795FS-20d | 2.5d | 0d |  |  | Joe |
| 738 | 1.4.1.4.1.4.2.2 | Confirm and Refine Network Requirements |  | 0.5d | 2008-10-15 | 2008-10-16 | 737 | 2.5d | 0d |  |  | Joe |
| 739 | 1.4.1.4.1.4.2.3 | Confirm and Refine Data Sharing Requirements |  | 0.5d | 2008-10-16 | 2008-10-16 | 738 | 2.5d | 0d |  |  | Joe |
| 740 | 1.4.1.4.1.4.2.4 | Confirm and Refine Local Printing Requirements |  | 0.5d | 2008-10-16 | 2008-10-17 | 739 | 2.5d | 0d |  |  | Joe |
| 741 | 1.4.1.4.1.4.2.5 | Confirm and Refine Client Machine Resource Requirements |  | 0.5d | 2008-10-17 | 2008-10-17 | 740 | 2.5d | 0d |  |  | Joe |
| 742 | 1.4.1.4.1.4.2.6 | Confirm and Refine Application Server Resource Requirements |  | 0.5d | 2008-10-17 | 2008-10-20 | 741 | 2.5d | 0d |  |  | Joe |
| 743 | 1.4.1.4.1.4.2.7 | Confirm and Refine Database Server Resource Requirements |  | 0.5d | 2008-10-20 | 2008-10-20 | 742 | 2.5d | 0d |  |  | Joe |
| 744 | 1.4.1.4.1.4.2.8 | Confirm and Refine Operating System Requirements |  | 0.5d | 2008-10-20 | 2008-10-21 | 743 | 2.5d | 0d |  |  | Joe |
| 745 | 1.4.1.4.1.4.2.9 | Confirm and Refine Communication Requirements |  | 0.5d | 2008-10-21 | 2008-10-21 | 744 | 2.5d | 0d |  |  | Joe |
| 746 | 1.4.1.4.1.4.2.10 | Confirm and Refine Peripheral Requirements |  | 0.5d | 2008-10-21 | 2008-10-22 | 745 | 2.5d | 0d |  |  | Joe |

| ID | WBS | Task | Duration | Start | Finish | Predecessors | Total slack | Free slack | Work | Text1 |
| --- | --- | --- | --- | --- | --- | --- | --- | --- | --- | --- |
| 747 | 1.4.1.4.1.4.3 | **Confirm Standard & Procedures** | 8.5d | 2008-10-22 | 2008-11-03 |  | 2.5d |  |  |  |
| 748 | 1.4.1.4.1.4.3.1 | Confirm Tech Roles/Resp for Prod. Environment | 0.5d | 2008-10-22 | 2008-10-22 | 746 | 2.5d | 0d |  | Joe |
| 749 | 1.4.1.4.1.4.3.2 | Confirm Production Support Agreements | 0.5d | 2008-10-22 | 2008-10-23 | 748 | 2.5d | 0d |  | Joe |
| 750 | 1.4.1.4.1.4.3.3 | Operational Procedures | 0.5d | 2008-10-23 | 2008-10-23 | 749 | 2.5d | 0d |  | Joe |
| 751 | 1.4.1.4.1.4.3.4 | Confirm & Refine System Availabilty | 0.5d | 2008-10-23 | 2008-10-24 | 750 | 2.5d | 0d |  | Joe |
| 752 | 1.4.1.4.1.4.3.5 | **Security Procedures** | 2d | 2008-10-24 | 2008-10-28 |  | 2.5d | 0d |  |  |
| 753 | 1.4.1.4.1.4.3.5.1 | Confirm & Refine Operating System Security | 1d | 2008-10-24 | 2008-10-27 | 751 | 2.5d | 0d |  | Joe |
| 754 | 1.4.1.4.1.4.3.5.2 | Confirm & Refine Application Security | 1d | 2008-10-27 | 2008-10-28 | 753 | 2.5d |  |  | Yvonne |
| 755 | 1.4.1.4.1.4.3.6 | Confirm & Refine Back-Up and Recovery Procedures | 0.5d | 2008-10-28 | 2008-10-28 | 752 | 2.5d | 0d |  | Joe |
| 756 | 1.4.1.4.1.4.3.7 | Confirm & Refine System Administration Procedures | 0.5d | 2008-10-28 | 2008-10-29 | 755 | 2.5d | 0d |  | Joe |
| 757 | 1.4.1.4.1.4.3.8 | Confirm Network Management Policies | 0.5d | 2008-10-29 | 2008-10-29 | 756 | 2.5d | 0d |  | Joe |
| 758 | 1.4.1.4.1.4.3.9 | Confirm Resource Management/Monitoring Policies | 0.5d | 2008-10-29 | 2008-10-30 | 757 | 2.5d | 0d |  | Joe |
| 759 | 1.4.1.4.1.4.3.10 | Confirm Change Control Procedures | 0.5d | 2008-10-30 | 2008-10-30 | 758 | 2.5d | 0d |  | Joe |
| 760 | 1.4.1.4.1.4.3.11 | Confirm Job Scheduling Process | 0.5d | 2008-10-30 | 2008-10-31 | 759 | 2.5d | 0d |  | Joe |
| 761 | 1.4.1.4.1.4.3.12 | Contingency Planning | 0.5d | 2008-10-31 | 2008-10-31 | 760 | 2.5d | 0d |  | Joe |
| 762 | 1.4.1.4.1.4.3.13 | Confirm Problem/Error Mgmt/Tracking Requirements | 0.5d | 2008-10-31 | 2008-11-03 | 761 | 2.5d | 0d |  | Joe |
| 763 | 1.4.1.4.1.4.3.14 | Confirm Archiving & Purging Requirements (for DB, Reports, Logs, etc.) | 0.5d | 2008-11-03 | 2008-11-03 | 762 | 2.5d | 0d |  | Joe |
| 764 | 1.4.1.4.1.5 | Revise Infrastructure Requirement Document | 1d | 2008-11-03 | 2008-11-04 | 763 | 2.5d | 0d |  | Joe |
| 765 | 1.4.1.4.1.6 | Prepare PreInstallation Checklist | 2d | 2008-11-04 | 2008-11-06 | 764 | 2.5d | 0d |  | Joe |
| 766 | 1.4.1.4.1.7 | Review Production Environment Design | 1d | 2008-11-06 | 2008-11-07 | 765 | 2.5d | 0d |  | Joe |
| 767 | 1.4.1.4.1.8 | Obtain Approval of Production Environment | 1d | 2008-11-07 | 2008-11-10 | 766 | 2.5d |  |  |  |
| 768 | 1.4.1.4.2 | Middleware - Milestones | 1d | 2007-01-01 | 2007-01-01 |  | 487.03d |  |  |  |
| 769 | 1.4.1.4.3 | Extranet - Milestones | 1d | 2007-01-01 | 2007-01-01 |  | 487.03d |  |  |  |
| 770 | 1.4.2 | **Integrate Stage** | 487.03d | 2007-01-01 | 2008-11-12 |  | 1d |  | 1678.14h |  |
| 771 | 1.4.2.1 | **Process Track** | 24d | 2007-04-24 | 2007-05-28 |  | 382.48d |  |  |  |
| 772 | 1.4.2.1.1 | Measurement Plan | 6d | 2007-04-24 | 2007-05-02 | 429FS-5d | 382.48d | 0d |  | Rob?, Sonia |
| 773 | 1.4.2.1.2 | Governance | 6d | 2007-05-02 | 2007-05-10 | 772 | 382.48d | 0d |  | Rob?, Sonia |
| 774 | 1.4.2.1.3 | Continuous Process Improvement | 6d | 2007-05-10 | 2007-05-18 | 773 | 382.48d | 0d |  | Rob?, Sonia |
| 775 | 1.4.2.1.4 | Business Model Vitality | 6d | 2007-05-18 | 2007-05-28 | 774 | 382.48d |  |  | Rob?, Sonia |

| ID | WBS | Task | Duration | Start | Finish | Predecessors | Total slack | Free slack | Resources | Work | Text1 |
| --- | --- | --- | --- | --- | --- | --- | --- | --- | --- | --- | --- |
| 776 | 1.4.2.2 | **System & Integration Testing** | 487.03d | 2007-01-01 | 2008-11-12 |  | 1d | 0d |  | 1125.34h |  |
| 777 | 1.4.2.2.1 | Confirm Deliverable Templates | 1d | 2007-04-17 | 2007-04-18 | 429FS-10d | 0d |  |  |  | Rick |
| 778 | 1.4.2.2.2 | **Develop Testing Strategy and Plan** | 33.98d | 2007-04-18 | 2007-06-05 |  | 0d |  |  | 47.74h |  |
| 779 | 1.4.2.2.2.1 | **Prepare Test Strategy document** | 32.48d | 2007-04-18 | 2007-06-04 |  | 0d |  |  | 47.74h |  |
| 780 | 1.4.2.2.2.1.1 | Define Scope of The System Test and Cycles | 26d | 2007-04-18 | 2007-05-24 | 777 | 0d |  |  |  | Lois, Ba |
| 781 | 1.4.2.2.2.1.2 | Define Test Cycles to Address Integration Testing | 2.98d | 2007-05-24 | 2007-05-29 | 780 | 0d |  | Business Analyst; Extranet Designer | 47.74h | Lois, Ba |
| 782 | 1.4.2.2.2.1.3 | Determine System Test Team Members and Responsibilities | 0.5d | 2007-05-29 | 2007-05-30 | 781 | 0d |  |  |  | Rick |
| 783 | 1.4.2.2.2.1.4 | Confirm Required Physical Computer Resources | 0.5d | 2007-05-30 | 2007-05-30 | 782 | 2.5d |  |  |  | Rick |
| 784 | 1.4.2.2.2.1.5 | Define access and security controls | 1d | 2007-05-30 | 2007-05-31 | 782 | 0d |  |  |  | Yvonne |
| 785 | 1.4.2.2.2.1.6 | Document Operational Plan | 2d | 2007-05-31 | 2007-06-04 | 784 | 0d |  |  |  | Rick |
| 786 | 1.4.2.2.2.2 | **Complete the System Test Team Orientation** | 0.5d | 2007-06-04 | 2007-06-04 |  | 376.5d |  |  |  |  |
| 787 | 1.4.2.2.2.2.1 | Conduct walk-through of test plan, roles, responsibilities | 0.5d | 2007-06-04 | 2007-06-04 | 785 | 376.5d | 0d |  |  | Rick |
| 788 | 1.4.2.2.2.3 | Obtain Approval of System Test Strategy & Plan | 1d | 2007-06-04 | 2007-06-05 | 787 | 376.5d |  |  |  |  |
| 789 | 1.4.2.2.3 | **Develop System Test Scripts** | 18.2d | 2007-01-01 | 2007-01-25 |  | 469.83d |  |  | 137.6h |  |
| 790 | 1.4.2.2.3.1 | Technical Integration Scripts - Revise Unit Test Cases | 17.2d | 2007-01-01 | 2007-01-24 |  | 469.83d | 0d | Legacy Developer | 137.6h | Ba |
| 791 | 1.4.2.2.3.2 | Obtain Approval on Test Scripts | 1d | 2007-01-24 | 2007-01-25 | 790 | 469.83d |  |  |  |  |
| 792 | 1.4.2.2.4 | **Unit to System Test Migration** | 3d | 2007-06-04 | 2007-06-07 |  | 0d |  |  |  |  |
| 793 | 1.4.2.2.4.1 | Plan Unit to System Test Migration | 1d | 2007-06-04 | 2007-06-05 | 779, 678 | 0d |  |  |  | Joe |
| 794 | 1.4.2.2.4.2 | Execute Unit to System Test Migration | 2d | 2007-06-05 | 2007-06-07 | 793 | 0d |  |  |  | Joe |
| 795 | 1.4.2.2.5 | **Execute System/Integration Test** | 378d | 2007-06-01 | 2008-11-12 |  | 0d |  |  | 940h |  |
| 796 | 1.4.2.2.5.1 | **Prepare Envrionment and Conduct Mock Conversions** | 6d | 2007-06-07 | 2007-06-15 |  | 0d |  |  |  |  |
| 797 | 1.4.2.2.5.1.1 | Setup system test environment | 6d | 2007-06-07 | 2007-06-15 | 794 | 0d |  |  |  | Lois |
| 798 | 1.4.2.2.5.2 | **Conduct System Testing** | 368d | 2007-06-15 | 2008-11-12 |  | 0d |  |  | 504h |  |
| 799 | 1.4.2.2.5.2.1 | Conversion - Mock Runs | 68d | 2007-06-15 | 2007-09-19 | 797 | 0d |  |  |  | Ba, Lois |
| 800 | 1.4.2.2.5.2.2 | Execute Test Cycles | 300d | 2007-09-19 | 2008-11-12 | 799 | 0d |  |  |  | Lois, Ba |
| 801 | 1.4.2.2.5.2.3 | Execute Technical Integration Cycles | 31.5d | 2007-09-05 | 2007-10-18 | 800SS-10d | 278.5d |  | Business Analyst; Extranet Designer | 504h | Ba, Lois |
| 802 | 1.4.2.2.5.2.4 | Evaluate System Test Results | 70d | 2007-09-13 | 2007-12-20 | 800SS-4d | 81.35d | 0d |  |  | Lois, Ba |
| 803 | 1.4.2.2.5.2.5 | Assess Cutover Readiness | 0.9d | 2007-12-20 | 2007-12-20 | 802 | 81.35d | 0d |  |  | Rob |

| ID | WBS | Task | Duration | Start | Finish | Predecessors | Total slack | Free slack | Constraint | Resources | Work | Text1 |
| --- | --- | --- | --- | --- | --- | --- | --- | --- | --- | --- | --- | --- |
| 804 | 1.4.2.2.5.3 | **Provide Test Support** | 75d | 2007-06-01 | 2007-09-14 |  | 303d |  |  |  | 436h |  |
| 805 | 1.4.2.2.5.3.1 | **Provide System Test Support** | 48d | 2007-06-01 | 2007-08-08 |  | 330d |  |  |  | 384h |  |
| 806 | 1.4.2.2.5.3.1.1 | Functional Support | 20d | 2007-06-01 | 2007-06-29 | 798SS-10d | 358d |  | start no earlier than 2007-01-01 |  |  |  |
| 807 | 1.4.2.2.5.3.1.2 | Technical Support / Corrections | 48d | 2007-06-01 | 2007-08-08 | 798SS-10d | 330d |  |  | Reports Developer | 384h |  |
| 808 | 1.4.2.2.5.3.2 | Document and Log All Errors | 20d | 2007-06-08 | 2007-07-06 | 798SS-5d | 353d |  |  |  |  |  |
| 809 | 1.4.2.2.5.3.3 | Document and Resolve Specification or Design Changes | 10d | 2007-06-08 | 2007-06-22 | 798SS-5d | 363d |  |  |  |  | Tracey |
| 810 | 1.4.2.2.5.3.4 | File System Test Results for Completed Test Cycles | 9d | 2007-06-12 | 2007-06-25 | 798SS-3d | 362d |  |  |  |  | Lois |
| 811 | 1.4.2.2.5.3.5 | Internal Audit | 6.5d | 2007-06-08 | 2007-06-18 | 798SS-5d | 366.5d |  |  | Internal Audit | 52h | Rick, Rob |
| 812 | 1.4.2.2.5.3.6 | Submit System Test Results for Approval | 1d | 2007-09-13 | 2007-09-14 | 802SS | 303d |  |  |  |  |  |
| 813 | 1.4.2.3 | **Stress Testing** | 147.59d | 2007-01-01 | 2007-07-25 |  | 340.45d |  |  |  | 476.8h |  |
| 814 | 1.4.2.3.1 | **Develop Stress Test Strategy/Plan** | 9.7d | 2007-01-01 | 2007-01-12 |  | 340.45d |  |  |  |  |  |
| 815 | 1.4.2.3.1.1 | Determine Scope | 1d | 2007-01-01 | 2007-01-01 |  | 340.45d | 0d |  |  |  | Tracey |
| 816 | 1.4.2.3.1.2 | Determine Team Members | 1d | 2007-01-02 | 2007-01-02 | 815 | 340.45d | 0d |  |  |  | Rick |
| 817 | 1.4.2.3.1.3 | Determine System Resources | 1d | 2007-01-03 | 2007-01-03 | 816 | 340.45d | 0d |  |  |  | Joe |
| 818 | 1.4.2.3.1.4 | Determine Performance Criteria | 1.9d | 2007-01-04 | 2007-01-05 | 817 | 340.45d | 0d |  |  |  | Rob |
| 819 | 1.4.2.3.1.5 | Develop Stress Test Plan | 3.8d | 2007-01-05 | 2007-01-11 | 818 | 340.45d | 0d |  |  |  | Ba, Rick |
| 820 | 1.4.2.3.1.6 | Obtain Approval on Strategy/Plan | 1d | 2007-01-11 | 2007-01-12 | 819 | 340.45d | 0d |  |  |  |  |
| 821 | 1.4.2.3.2 | **Conduct Stress Testing** | 128.29d | 2007-01-12 | 2007-07-11 |  | 340.45d | 0d |  |  | 416h |  |
| 822 | 1.4.2.3.2.1 | Setup Stress Test Instance | 2d | 2007-01-12 | 2007-01-16 | 820 | 340.45d | 0d |  |  |  | Lois |
| 823 | 1.4.2.3.2.2 | Building Scripts in Load Runner | 14d | 2007-01-16 | 2007-02-05 | 822 | 340.45d | 0d |  | Business Solutions User Support Analyst | 112h | Tracey |
| 824 | 1.4.2.3.2.3 | Conduct Mock Conversions | 74.29d | 2007-02-05 | 2007-05-18 | 823 | 340.45d | 0d |  |  |  | Ba |
| 825 | 1.4.2.3.2.4 | Execute Stress Testing | 38d | 2007-05-18 | 2007-07-11 | 824 | 340.45d | 0d |  | Business Solutions User Support Analyst | 304h | Tracey |
| 826 | 1.4.2.3.3 | **Evaluate Results and Conduct Tuning** | 13.6d | 2007-07-04 | 2007-07-24 |  | 340.45d |  |  |  | 60.8h |  |
| 827 | 1.4.2.3.3.1 | Review System Performance-Related Criteria | 1d | 2007-07-04 | 2007-07-05 | 825FS-5d | 340.45d | 0d |  |  |  | Joe |
| 828 | 1.4.2.3.3.2 | Review Test Performance Results | 1d | 2007-07-05 | 2007-07-06 | 827 | 340.45d | 0d |  |  |  | Joe |
| 829 | 1.4.2.3.3.3 | Identify Environmental Tuning Options | 1d | 2007-07-06 | 2007-07-09 | 828 | 340.45d | 0d |  |  |  | Joe |
| 830 | 1.4.2.3.3.4 | Identify Application Tuning Options | 1d | 2007-07-09 | 2007-07-10 | 829 | 340.45d | 0d |  |  |  | Joe |
| 831 | 1.4.2.3.3.5 | Identify Database Tuning Options | 1d | 2007-07-10 | 2007-07-11 | 830 | 340.45d | 0d |  |  |  | Joe |
| 832 | 1.4.2.3.3.6 | Complete System Tuning | 1d | 2007-07-11 | 2007-07-12 | 831 | 340.45d | 0d |  |  |  | Joe |
| 833 | 1.4.2.3.3.7 | ReTest After Tuning | 7.6d | 2007-07-12 | 2007-07-24 | 832 | 340.45d | 0d |  | Business Solutions User Support Analyst | 60.8h | Tracey |
| 834 | 1.4.2.3.4 | Establish Ongoing System Tuning Process | 1d | 2007-07-24 | 2007-07-25 | 833 | 340.45d |  |  |  |  | Joe |

| ID | WBS | Task | Duration | Start | Finish | Predecessors | Total slack | Free slack | Constraint | Resources | Work | Text1 |
| --- | --- | --- | --- | --- | --- | --- | --- | --- | --- | --- | --- | --- |
| 835 | 1.4.2.4 | **Technical Infrastructure Track** | 30.5d | 2007-06-01 | 2007-07-13 |  | 348.5d |  |  |  | 76h |  |
| 836 | 1.4.2.4.1 | **Productionalize Infrastructure's Transition to Data Centre Operations** | 30.5d | 2007-06-01 | 2007-07-13 |  | 348.5d |  |  |  | 76h |  |
| 837 | 1.4.2.3.1.3 | **Productionalize Infrastructure** | 21d | 2007-06-01 | 2007-07-02 |  | 348.5d |  |  |  | 32h |  |
| 838 | 1.4.2.3.1.3.1 | **Implement Production Environment** | 14d | 2007-06-01 | 2007-06-21 |  | 348.5d |  |  |  | 32h |  |
| 839 | 1.4.2.3.1.3.1.1 | **Implement Revised Standards, Procedures & Policies** | 10d | 2007-06-01 | 2007-06-15 |  | 348.5d |  |  |  | 16h |  |
| 840 | 1.4.2.3.1.3.1.1.1 | Backup / Restore | 2d | 2007-06-01 | 2007-06-05 | 795SS | 348.5d | 0d | start no earlier than 2007-01-01 |  |  | Joe |
| 841 | 1.4.2.3.1.3.1.1.2 | Recovery / Restart | 2d | 2007-06-05 | 2007-06-07 | 840 | 348.5d | 0d |  |  |  | Joe |
| 842 | 1.4.2.3.1.3.1.1.3 | Job scheduling | 4d | 2007-06-07 | 2007-06-13 | 841 | 348.5d | 0d |  |  |  | Joe |
| 843 | 1.4.2.4.1.1.1.1.4 | Fail Over | 1d | 2007-06-13 | 2007-06-14 | 842 | 348.5d | 0d |  | Server Admin; Network Admin | 16h | Joe |
| 844 | 1.4.2.3.1.3.1.1.4 | System Messages and Actions | 1d | 2007-06-14 | 2007-06-15 | 843 | 348.5d | 0d |  |  |  | Joe |
| 845 | 1.4.2.3.1.3.1.2 | **Implement Database Authorization and Security Concept** | 2d | 2007-06-15 | 2007-06-19 |  | 348.5d | 0d |  |  | 16h |  |
| 846 | 1.4.2.3.1.3.1.2.1 | Implement Database Security Concept | 1d | 2007-06-15 | 2007-06-18 | 844 | 348.5d | 0d |  | Server Admin | 8h | Joe |
| 847 | 1.4.2.3.1.3.1.2.2 | Implement Operating System Security | 1d | 2007-06-18 | 2007-06-19 | 846 | 348.5d |  |  | Server Admin | 8h | Joe |
| 848 | 1.4.2.3.1.3.1.3 | Implement Revised Resource Management/Monitoring Policies | 1d | 2007-06-19 | 2007-06-20 | 845 | 348.5d | 0d |  |  |  | Joe |
| 849 | 1.4.2.3.1.3.1.4 | Update Hardware and Software Inventory | 1d | 2007-06-20 | 2007-06-21 | 848 | 348.5d | 0d |  |  |  | Joe |
| 850 | 1.4.2.3.1.3.2 | Update Help Desk & Procedures | 1d | 2007-06-21 | 2007-06-22 | 849 | 348.5d | 0d |  |  |  | Joe |
| 851 | 1.4.2.3.1.3.3 | Update Configuration Management/Change Control Procedures | 1d | 2007-06-22 | 2007-06-25 | 850 | 348.5d | 0d |  |  |  | Joe |
| 852 | 1.4.2.3.1.3.4 | Update Hardware/Software Upgrade Procedures | 1d | 2007-06-25 | 2007-06-26 | 851 | 348.5d | 0d |  |  |  | Joe |
| 853 | 1.4.2.3.1.3.5 | **Tech support training for Fail Over** | 3d | 2007-06-26 | 2007-06-29 |  | 348.5d | 0d |  |  |  |  |
| 854 | 1.4.2.3.1.3.5.1 | Operations Staff | 1d | 2007-06-26 | 2007-06-27 | 852 | 348.5d | 0d |  |  |  | Joe |
| 855 | 1.4.2.3.1.3.5.2 | Help Desk | 1d | 2007-06-27 | 2007-06-28 | 854 | 348.5d | 0d |  |  |  | Joe |
| 856 | 1.4.2.3.1.3.5.3 | Security Admin | 1d | 2007-06-28 | 2007-06-29 | 855 | 348.5d |  |  |  |  | Joe,Yvonne |
| 857 | 1.4.2.3.1.3.6 | Review Training Plan with Internal Audit | 1d | 2007-06-29 | 2007-07-02 | 853 | 348.5d | 0d |  |  |  | Joe |
| 858 | 1.4.2.3.1.4 | **Acceptance of Production Environment** | 8.5d | 2007-07-02 | 2007-07-12 |  | 348.5d | 0d |  |  | 44h |  |
| 859 | 1.4.2.3.1.4.1 | Test Production Environment | 1d | 2007-07-02 | 2007-07-03 | 857 | 348.5d | 0d |  |  |  | Joe |
| 860 | 1.4.2.3.1.4.2 | Test Platform Components | 1d | 2007-07-03 | 2007-07-04 | 859 | 348.5d | 0d |  |  |  | Joe |
| 861 | 1.4.2.3.1.4.3 | Test Tools and Services | 1d | 2007-07-04 | 2007-07-05 | 860 | 348.5d | 0d |  |  |  | Joe |
| 862 | 1.4.2.3.1.4.4 | Update Revised Disaster Recovery Plan | 5.5d | 2007-07-05 | 2007-07-12 | 861 | 348.5d |  |  | Server Admin | 44h | Joe |
| 863 | 1.4.2.3.1.5 | Ongoing Tech. Infrastructure Review with Internal Audit | 1d | 2007-07-12 | 2007-07-13 | 858 | 348.5d |  |  |  |  |  |

| ID | WBS | Task | Duration | Start | Finish | Predecessors | Total slack | Free slack | Constraint | Resources | Work | Text1 |
| --- | --- | --- | --- | --- | --- | --- | --- | --- | --- | --- | --- | --- |
| 864 | 1.4.3 | **Implement Stage (All Tracks)** | 283.53d | 2007-01-01 | 2008-01-31 |  | 204.5d |  |  |  | 290h |  |
| 865 | 1.4.3.1 | **Execute Cutover and Rollout** | 283.53d | 2007-01-01 | 2008-01-31 |  | 204.5d |  |  |  | 290h |  |
| 866 | 1.4.3.1.1 | **System Test to Production Migration** | 4d | 2007-01-01 | 2007-01-04 |  | 319.38d |  |  |  |  |  |
| 867 | 1.4.3.1.1.1 | Plan System Test to Production Transfer | 4d | 2007-01-01 | 2007-01-04 | 776SS | 319.38d | 0d |  |  |  | Joe, Ba |
| 868 | 1.4.3.1.2 | **Production Readiness** | 8d | 2007-01-05 | 2007-01-16 |  | 319.38d | 0d |  |  |  |  |
| 869 | 1.4.3.1.2.1 | Setup Database | 3d | 2007-01-05 | 2007-01-09 | 867 | 319.38d | 0d |  |  |  | Joe |
| 870 | 1.4.3.1.2.2 | Transfer to Production | 3d | 2007-01-10 | 2007-01-12 | 869 | 321.38d |  |  |  |  | Joe |
| 871 | 1.4.3.1.2.3 | Setup Security | 5d | 2007-01-10 | 2007-01-16 | 869 | 319.38d |  |  |  |  | Yvonne |
| 872 | 1.4.3.1.3 | **Validate Cutover Readiness** | 257.63d | 2007-01-01 | 2007-12-26 |  | 230.4d |  |  |  | 46h |  |
| 873 | 1.4.3.1.3.1 | Verify execution of organizational and facilities changes | 2.05d | 2007-01-01 | 2007-01-03 | 867FS-5d | 473.78d | 0d | start no earlier than 2007-01-01 | Operations Manager | 16.4h | Ops Mgr |
| 874 | 1.4.3.1.3.2 | Ensure end users training plan has been executed | 1d | 2007-01-03 | 2007-01-04 | 873 | 473.78d | 0d |  | Operations Manager | 8h | Ops Mgr |
| 875 | 1.4.3.1.3.3 | Ensure go live support model is in place | 1.8d | 2007-01-04 | 2007-01-05 | 874 | 473.78d | 0d |  | Operations Manager | 14.4h | Ops Mgr |
| 876 | 1.4.3.1.3.4 | Verify execution of all security and controls procedures | 2d | 2007-01-05 | 2007-01-09 | 875 | 473.78d | 0d |  |  |  | Yvonne,Joe |
| 877 | 1.4.3.1.3.5 | Ensure controlled user startup plan is ready | 1.8d | 2007-01-09 | 2007-01-11 | 876 | 473.78d | 0d |  |  |  | Rob |
| 878 | 1.4.3.1.3.6 | Ensure all areas involved in detailed cutover timeline are ready | 1d | 2007-01-11 | 2007-01-12 | 877 | 473.78d | 0d |  |  |  | Rick |
| 879 | 1.4.3.1.3.7 | Ensure contingency plan is complete/validated | 2.8d | 2007-01-12 | 2007-01-17 | 878 | 473.78d | 0d |  |  |  | Rick |
| 880 | 1.4.3.1.3.8 | Schedule and conduct final cutover briefing | 1.8d | 2007-01-17 | 2007-01-19 | 879 | 473.78d |  |  |  |  | Rick |
| 881 | 1.4.3.1.3.9 | Make final go/no go decision | 1.8d | 2007-12-20 | 2007-12-24 | 803 | 230.4d | 0d |  |  |  | Sandeep |
| 882 | 1.4.3.1.3.10 | End User Information Sessions | 0.9d | 2007-12-24 | 2007-12-25 | 881 | 230.4d | 0d |  | Operations Manager | 7.2h | Rob |
| 883 | 1.4.3.1.3.11 | Obtain final approval for Cutover | 1d | 2007-12-25 | 2007-12-26 | 882 | 230.4d |  |  |  |  |  |
| 884 | 1.4.3.1.4 | **Execute Cutover Timeline** | 271.53d | 2007-01-17 | 2008-01-31 |  | 204.5d |  |  |  | 244h |  |
| 885 | 1.4.3.1.4.1 | Test final production environment | 3d | 2007-01-17 | 2007-01-19 | 868 | 319.38d | 0d |  |  |  | Joe,Lois,Ba |
| 886 | 1.4.3.1.4.2 | **Convert Data** | 268.53d | 2007-01-22 | 2008-01-31 |  | 99.5d | 0d |  |  | 244h |  |
| 887 | 1.4.3.1.4.2.1 | Setups | 2d | 2007-01-22 | 2007-01-23 | 885 | 319.38d | 238.03d |  |  |  | Lois |

| ID | WBS | Task | Type | Duration | Start | Finish | Predecessors | Total slack | Free slack | Constraint | Resources | Work | Text1 |
| --- | --- | --- | --- | --- | --- | --- | --- | --- | --- | --- | --- | --- | --- |
| 888 | 1.4.3.1.4.2.2 | **Customers** |  | 34.5d | 2007-12-14 | 2008-01-31 |  | 84.6d |  |  |  | 244h |  |
| 889 | 1.4.3.1.4.2.2.1 | Extract, Load, Import |  | 30.5d | 2007-12-20 | 2008-01-31 | 803SS, 887SS | 81.35d | 0d | start no earlier than 2007-01-01 | Business Analyst | 244h | Les, Ba, CIF |
| 890 | 1.4.3.1.4.2.2.2 | Reconcile |  | 6.25d | 2007-12-14 | 2007-12-24 | 889SS-4d | 109.6d | 0d |  |  |  | Lois |
| 891 | 1.4.3.1.4.2.2.3 | Exception Handling |  | 6.25d | 2007-12-19 | 2007-12-27 | 890FS-3d | 109.6d | 0d |  |  |  | Lois |
| 892 | 1.4.3.1.4.2.3 | **Invoices** |  | 21.9d | 2007-12-18 | 2008-01-17 |  | 109.6d |  |  |  |  |  |
| 893 | 1.4.3.1.4.2.3.1 | Extract, Load, Import |  | 16.4d | 2007-12-18 | 2008-01-09 | 891FS-7d | 109.6d | 0d |  |  |  | Les, Ba |
| 894 | 1.4.3.1.4.2.3.2 | Reconcile |  | 12.5d | 2007-12-31 | 2008-01-17 | 893FS-7d | 109.6d |  |  |  |  | Lois |
| 895 | 1.5.3.1.4.2.5 | Manual Transactions (posted dated chqs?) |  | 12.5d | 2007-12-21 | 2008-01-09 | 891FS-4d | 116d |  |  |  |  |  |
| 896 | 1.4.3.1.4.3 | Ongoing Cutover Activities Monitoring |  | 1d | 2007-12-24 | 2007-12-25 | 881 | 231.3d |  |  |  |  | Rick |
| 897 | 1.4.3.1.4.4 | Review Open Issues |  | 1d | 2007-12-24 | 2007-12-25 | 881 | 231.3d |  |  |  |  | Rick |
| 898 | 1.4.3.2 | **Post Implementation Support** |  | 105d | 2007-01-11 | 2007-06-06 |  | 375.03d |  |  |  |  |  |
| 899 | 1.4.3.2.1 | **Go Live** |  | 1d | 2007-01-11 | 2007-01-11 |  | 375.03d |  |  |  |  |  |
| 900 | 1.4.3.2.1.1 | Begin entering live transactions into system and using new support model | milestone | 0d | 2007-01-11 | 2007-01-11 | 886SS-7d | 375.03d | 0d |  |  |  |  |
| 901 | 1.4.3.2.1.2 | Continue execution of controlled user startup plan |  | 1d | 2007-01-11 | 2007-01-11 | 886SS-7d | 479.03d |  |  |  |  |  |
| 902 | 1.4.3.2.2 | Create measures/checks to validate user entry for reasonableness and accuracy |  | 2d | 2007-01-11 | 2007-01-12 | 886SS-7d | 438.03d | 0d |  |  |  | Lois |
| 903 | 1.4.3.2.3 | Post Go-Live Training |  | 40d | 2007-01-15 | 2007-03-09 | 902 | 438.03d |  |  |  |  |  |
| 904 | 1.4.3.2.4 | Provide Post Implementation Support |  | 100d | 2007-01-11 | 2007-05-30 | 900 | 375.03d | 0d |  |  |  | Ba |
| 905 | 1.4.3.2.5 | Lessons Learned |  | 5d | 2007-05-31 | 2007-06-06 | 904 | 375.03d |  |  |  |  |  |
| 906 | 1.5 | **Program Management - Ongoing** |  | 1d | 2007-01-01 | 2007-01-01 |  | 487.03d |  |  |  |  |  |
| 907 | 1.5.1 | **People Management** |  | 1d | 2007-01-01 | 2007-01-01 |  | 487.03d |  |  |  |  |  |
| 908 | 1.5.1.1 | Confirm Project Structure & Resources |  | 1d | 2007-01-01 | 2007-01-01 |  | 487.03d |  |  |  |  |  |
| 909 | 1.5.1.2 | Ongoing Team Mgmt |  | 1d | 2007-01-01 | 2007-01-01 |  | 487.03d |  |  |  |  |  |
| 910 | 1.5.1.3 | Ongoing Stakeholder Mgmt |  | 1d | 2007-01-01 | 2007-01-01 |  | 487.03d |  |  |  |  |  |
| 911 | 1.5.2 | **Work Management** |  | 1d | 2007-01-01 | 2007-01-01 |  | 487.03d |  |  |  |  |  |
| 912 | 1.5.2.1 | Ongoing Monitor & Update Project Plan |  | 1d | 2007-01-01 | 2007-01-01 |  | 487.03d |  |  |  |  |  |
| 913 | 1.5.2.2 | Ongoing Scope Control |  | 1d | 2007-01-01 | 2007-01-01 |  | 487.03d |  |  |  |  |  |
| 914 | 1.5.2.3 | Ongoing Issue Resolution |  | 1d | 2007-01-01 | 2007-01-01 |  | 487.03d |  |  |  |  |  |
| 915 | 1.5.2.4 | Weekly Team Meetings |  | 1d | 2007-01-01 | 2007-01-01 |  | 487.03d |  |  |  |  |  |
| 916 | 1.5.2.5 | Integration Meetings |  | 1d | 2007-01-01 | 2007-01-01 |  | 487.03d |  |  |  |  |  |
| 917 | 1.5.2.6 | Weekly Sponsor Meetings |  | 1d | 2007-01-01 | 2007-01-01 |  | 487.03d |  |  |  |  |  |
| 918 | 1.5.2.7 | Monthly Steering Committee Meetings |  | 1d | 2007-01-01 | 2007-01-01 |  | 487.03d |  |  |  |  |  |
| 919 | 1.5.2.8 | Compare Development Deliverables |  | 1d | 2007-01-01 | 2007-01-01 |  | 487.03d |  |  |  |  |  |
| 920 | 1.5.3 | Ongoing Monitoring of Knowledge Management |  | 1d | 2007-01-01 | 2007-01-01 |  | 487.03d |  |  |  |  |  |
| 921 | 1.5.4 | Engagement Management |  | 1d | 2007-01-01 | 2007-01-01 |  | 487.03d |  |  |  |  |  |
| 922 | 1.5.5 | Ongoing Quality Assurance |  | 1d | 2007-01-01 | 2007-01-01 |  | 487.03d |  |  |  |  |  |
